# Diagnóstico predial y de tenencia

Schedule from MS Project, 2013-12-30 to 2014-07-10, costs in $.

## Calendars

- lunes a sabado con festivos: Mon-Sat 07:00-12:00, 14:00-17:00; Sun off. Exceptions (off unless hours are given): 2014-01-01 (festivo), 2014-01-06 (festivo), 2014-03-24 (festivo), 2014-04-17 to 2014-04-18 (festivo), 2014-05-01 (festivo), 2014-06-02 (festivo), 2014-06-23 (festivo), 2014-06-30 (festivo).

## Resources

| Resource |
| --- |
| Director de proyecto |
| Experto SIG |
| Experto Jurídico |
| Experto Social |
| Experto Catastral |
| Perito Avaluador |
| Profesional de apoyo sistemas |
| Auxiliar Administrativo |
| Técnicos de campo |
| Conductor |
| Digitadores |
| Control de Calidad |
| Gerente de Operaciones |
| Gerente general EVOLUTION |
| Gerente administrativa |
| Ingeniero Seguimiento de Proyecto |
| Coordinador de Información |
| Analistas de Información |
| Analistas SIG |
| Coordinador Desarrollo |
| Coordinador TICs |
| Experto Project |
| Supervisor FONDO |
| Aseguradora |
| Representante legal EVOLUTION |

## Schedule

| ID | WBS | Task | Type | Duration | Start | Finish | Predecessors | Total slack | Free slack | Resources | Work | Cost | Text27 | Text29 | Text30 |
| --- | --- | --- | --- | --- | --- | --- | --- | --- | --- | --- | --- | --- | --- | --- | --- |
| 1 | 1 | **Fase de actividades preliminares** |  | 23d | 2013-12-30 | 2014-01-27 |  | 0d |  |  | 1303h | 55,222,978.09 | 24 días | mar 28/01/14 | lun 30/12/13 |
| 2 | 1.1 | **Actividades legales** |  | 11d | 2013-12-30 | 2014-01-13 |  | 0d |  |  | 80h |  | 11 días | lun 13/01/14 | lun 30/12/13 |
| 3 | 1.1.1 | Firmar contrato |  | 1d | 2013-12-30 | 2013-12-31 |  | 0d |  | Auxiliar Administrativo | 8h |  | 1 día | mar 31/12/13 | lun 30/12/13 |
| 4 | 1.1.2 | Generar pólizas |  | 2d | 2013-12-31 | 2014-01-04 | 3SS+1d | 0d |  | Aseguradora | 16h |  | 2 días | sáb 04/01/14 | mar 31/12/13 |
| 5 | 1.1.3 | Legalizar pólizas |  | 2d | 2014-01-03 | 2014-01-08 | 4SS+2d | 0d |  | Aseguradora | 16h |  | 2 días | mié 08/01/14 | vie 03/01/14 |
| 6 | 1.1.4 | Aprobar pólizas |  | 3d | 2014-01-07 | 2014-01-13 | 5FS-2d | 0d |  | Supervisor FONDO | 24h |  | 3 días | lun 13/01/14 | mar 07/01/14 |
| 7 | 1.1.5 | Generar y firmar acta de inicio |  | 1d | 2014-01-10 | 2014-01-11 | 6FS-3d | 0d |  | Representante legal EVOLUTION; Supervisor FONDO | 16h |  | 1 día | sáb 11/01/14 | vie 10/01/14 |
| 8 | 1.1.6 | Acta de inicio firmada | milestone | 0d | 2014-01-10 | 2014-01-10 | 7FS-2d | 0d |  |  |  |  | 0 días | vie 10/01/14 | vie 10/01/14 |
| 9 | 1.2 | **Plan de trabajo** |  | 13d | 2014-01-13 | 2014-01-27 |  | 0d |  |  | 1223h | 55,222,978.09 | 14 días | mar 28/01/14 | lun 13/01/14 |
| 10 | 1.2.1 | Asistir a reunión de aclaraciones con interventoría |  | 2d | 2014-01-13 | 2014-01-14 | 8FS+2d | 0d |  | Director de proyecto [10%]; Perito Avaluador [10%]; Experto SIG [10%]; Gerente general EVOLUTION [10%]; Gerente de Operaciones [10%] | 320h | 4,247,921.39 | 2 días | mar 14/01/14 | lun 13/01/14 |
| 11 | 1.2.2 | Definir grupos de actividades |  | 1d | 2014-01-15 | 2014-01-15 | 10 | 3d | 0d | Director de proyecto [10%]; Gerente de Operaciones [10%]; Ingeniero Seguimiento de Proyecto [10%] | 50.4h | 2,123,960.7 | 1 día | mié 15/01/14 | mié 15/01/14 |
| 12 | 1.2.3 | Desagregar grupos en actividades |  | 1d | 2014-01-16 | 2014-01-16 | 11 | 3d | 0d | Director de proyecto [10%]; Gerente de Operaciones [10%]; Ingeniero Seguimiento de Proyecto [10%] | 50.4h | 2,123,960.7 | 1 día | jue 16/01/14 | jue 16/01/14 |
| 13 | 1.2.4 | Agregar actividades en paquetes de trabajo (actividades resumen) |  | 1d | 2014-01-17 | 2014-01-17 | 12 | 3d | 0d | Director de proyecto [10%]; Gerente de Operaciones [10%]; Ingeniero Seguimiento de Proyecto [10%] | 50.4h | 2,123,960.7 | 1 día | vie 17/01/14 | vie 17/01/14 |
| 14 | 1.2.5 | Estimar rendimientos y tiempos de actividades |  | 1d | 2014-01-18 | 2014-01-18 | 13 | 3d | 0d | Director de proyecto [10%]; Gerente de Operaciones [10%]; Perito Avaluador [10%]; Experto Social [10%]; Profesional de apoyo sistemas [10%]; Experto Catastral [10%] | 16.9h | 2,123,960.7 | 1 día | sáb 18/01/14 | sáb 18/01/14 |
| 15 | 1.2.6 | Asignar tiempos y recursos |  | 2d | 2014-01-20 | 2014-01-21 | 14 | 3d | 0d | Director de proyecto [10%]; Gerente de Operaciones [40%]; Perito Avaluador [10%]; Experto Social [10%]; Profesional de apoyo sistemas [10%]; Experto Catastral [10%] | 27.3h | 4,247,921.39 | 2 días | mar 21/01/14 | lun 20/01/14 |
| 16 | 1.2.7 | Generar cronograma |  | 2d | 2014-01-22 | 2014-01-23 | 15 | 3d |  | Gerente de Operaciones [10%]; Director de proyecto [10%] | 17.6h | 4,247,921.39 | 2 días | jue 23/01/14 | mié 22/01/14 |
| 17 | 1.2.8 | Generar documento de metodología |  | 11d | 2014-01-15 | 2014-01-27 | 10 | 0d |  | Auxiliar Administrativo [80%]; Gerente de Operaciones [80%]; Director de proyecto [20%]; Ingeniero Seguimiento de Proyecto [20%] | 537h | 21,239,606.95 | 11 días | mar 28/01/14 | mié 15/01/14 |
| 18 | 1.2.9 | Conformar plan de trabajo |  | 7d | 2014-01-20 | 2014-01-27 | 16FF, 17SS+4d | 0d |  | Auxiliar Administrativo [15%]; Gerente de Operaciones [50%]; Director de proyecto [10%]; Ingeniero Seguimiento de Proyecto [30%] | 153h | 12,743,764.17 | 7 días | lun 27/01/14 | lun 20/01/14 |
| 19 | 1.3 | Plan de trabajo (Entregable 1) generado | milestone | 0d | 2014-01-27 | 2014-01-27 | 18 | 0d |  |  |  |  | 0 días | lun 27/01/14 | lun 27/01/14 |
| 20 | 2 | **Fase de recepción y cargue de información** |  | 25d | 2014-01-14 | 2014-02-11 |  | 21d |  |  | 672.4h | 63,718,820.88 | 25 días | mar 11/02/14 | mar 14/01/14 |
| 21 | 2.1 | **Recepción de información** |  | 16d | 2014-01-14 | 2014-01-31 |  | 21d |  |  | 281.2h | 31,859,410.44 | 16 días | vie 31/01/14 | mar 14/01/14 |
| 22 | 2.1.1 | Entregar Información inicial |  | 1d | 2014-01-14 | 2014-01-14 | 7FS+1d | 21d | 0d | Supervisor FONDO | 8h |  | 1 día | mar 14/01/14 | mar 14/01/14 |
| 23 | 2.1.2 | Clasificar información recibida |  | 7d | 2014-01-15 | 2014-01-22 | 22 | 21d | 0d | Coordinador de Información [20%]; Analistas de Información [20%]; Analistas SIG [20%] | 114h | 12,743,764.17 | 7 días | mié 22/01/14 | mié 15/01/14 |
| 24 | 2.1.3 | Generar inventario de información recibida |  | 4d | 2014-01-23 | 2014-01-27 | 23 | 32d | 0d | Coordinador de Información [10%]; Analistas de Información [10%]; Analistas SIG [10%] | 84h | 10,619,803.48 | 4 días | lun 27/01/14 | jue 23/01/14 |
| 25 | 2.1.4 | Generar Inventario por municipio |  | 1d | 2014-01-28 | 2014-01-28 | 24 | 33d | 3d | Coordinador de Información [10%]; Analistas de Información [10%]; Analistas SIG [10%] | 16.8h | 2,123,960.7 | 1 día | mar 28/01/14 | mar 28/01/14 |
| 26 | 2.1.5 | Generar informe de inventario de información |  | 4d | 2014-01-25 | 2014-01-29 | 24FS-2d | 32d | 2d | Auxiliar Administrativo [50%]; Coordinador de Información [10%]; Analistas de Información [10%] | 50.4h | 6,371,882.09 | 4 días | mié 29/01/14 | sáb 25/01/14 |
| 27 | 2.1.6 | Entregar información de POT, EOT, PBOT |  | 10d | 2014-01-21 | 2014-01-31 | 22FS+5d | 30d | 0d | Supervisor FONDO | 8h |  | 10 días | vie 31/01/14 | mar 21/01/14 |
| 28 | 2.1.7 | Inventario de información (por municipio) generado | milestone | 0d | 2014-01-31 | 2014-01-31 | 25, 26, 27 | 30d | 0d |  |  |  | 0 días | vie 31/01/14 | vie 31/01/14 |

Notes:
- 19: Entregable 1 / La metodología detallada del trabajo con su respectivo cronograma de ejecución del estudio, detallando actividades, recursos, costos, fechas, hitos y entregables.

| ID | WBS | Task | Type | Duration | Start | Finish | Predecessors | Total slack | Free slack | Resources | Work | Cost | Text27 | Text29 | Text30 |
| --- | --- | --- | --- | --- | --- | --- | --- | --- | --- | --- | --- | --- | --- | --- | --- |
| 29 | 2.2 | **Preparación de información** |  | 11d | 2014-01-23 | 2014-02-04 |  | 21d |  |  | 308h | 21,239,606.96 | 11 días | mar 04/02/14 | jue 23/01/14 |
| 30 | 2.2.1 | Estructurar información alfanumérica (registros 1 y 2, Notariado y registro) |  | 6d | 2014-01-23 | 2014-01-29 | 23 | 21d | 0d | Coordinador de Información [10%]; Profesional de apoyo sistemas [200%]; Analistas de Información | 84h | 10,619,803.48 | 6 días | mié 29/01/14 | jue 23/01/14 |
| 31 | 2.2.2 | Estructurar información cartográfica en formatos de cargue |  | 6d | 2014-01-23 | 2014-01-29 | 23 | 26d | 0d | Experto Social; Analistas SIG | 80h | 10,619,803.48 | 6 días | mié 29/01/14 | jue 23/01/14 |
| 32 | 2.2.3 | Definir modelo de datos alfanumérico |  | 5d | 2014-01-30 | 2014-02-04 | 30 | 21d | 0d | Analistas de Información [10%]; Profesional de apoyo sistemas [50%]; Director de proyecto [10%]; Experto Catastral [10%] | 96h |  | 5 días | mar 04/02/14 | jue 30/01/14 |
| 33 | 2.2.4 | Estructurar base de datos geográfica (Geodatabase) |  | 3d | 2014-01-30 | 2014-02-01 | 31 | 26d | 0d | Experto Social [10%]; Experto Catastral [10%]; Analistas SIG [30%] | 48h |  | 3 días | sáb 01/02/14 | jue 30/01/14 |
| 34 | 2.3 | **Cargue de información** |  | 7d | 2014-02-03 | 2014-02-10 |  | 22d |  |  | 83.2h | 10,619,803.48 | 6 días | sáb 08/02/14 | lun 03/02/14 |
| 35 | 2.3.1 | Poblar modelo de datos alfanumérico |  | 4d | 2014-02-05 | 2014-02-08 | 32 | 21d | 0d | Coordinador de Información [10%]; Analistas de Información [10%]; Profesional de apoyo sistemas [10%] | 50.4h | 6,371,882.09 | 4 días | sáb 08/02/14 | mié 05/02/14 |
| 36 | 2.3.2 | Poblar la Geodatabase |  | 3d | 2014-02-03 | 2014-02-05 | 33 | 26d | 0d | Coordinador de Información [5%]; Analistas SIG [5%]; Profesional de apoyo sistemas [5%] | 32.8h | 4,247,921.39 | 3 días | mié 05/02/14 | lun 03/02/14 |
| 37 | 2.3.3 | Ejecutar cruce de bases de datos |  | 1d | 2014-02-10 | 2014-02-10 | 35 | 21d | 0d |  |  |  |  |  |  |
| 38 | 2.4 | Base de datos (Entregable 2) cargada | milestone | 0d | 2014-02-11 | 2014-02-11 | 35, 36, 28, 37FS+1d | 21d | 0d |  |  |  | 0 días | mar 11/02/14 | mar 11/02/14 |
| 39 | 3 | **Fase de análisis y diagnóstico de información** |  | 21d | 2014-02-12 | 2014-03-07 |  | 21d |  |  | 896.8h | 129,561,602.57 | 21 días | mar 25/02/14 | sáb 01/02/14 |
| 40 | 3.1 | **Análisis y diagnóstico de Información geográfica y alfanumérica** |  | 14d | 2014-02-12 | 2014-02-27 |  | 71d |  |  | 264h | 70,090,703.1 | 17 días | mar 25/02/14 | jue 06/02/14 |
| 41 | 3.1.1 | **Análisis y diagnóstico de Magangué (Bolívar)** |  | 6d | 2014-02-12 | 2014-02-18 |  | 71d |  |  | 24h | 6,371,882.1 | 2 días | vie 07/02/14 | jue 06/02/14 |
| 42 | 3.1.1.1 | Generar diagnostico de informacion alfanumerica (Catastro y Registro) |  | 3d | 2014-02-12 | 2014-02-14 | 38 | 71d | 0d |  |  |  |  |  |  |
| 43 | 3.1.1.2 | Generar diagnóstico de capas (Geodatabase) |  | 1d | 2014-02-15 | 2014-02-15 | 42 | 79d | 0d | Analistas SIG | 8h | 2,123,960.7 | 1 día | jue 06/02/14 | jue 06/02/14 |
| 44 | 3.1.1.3 | Generar cruce alfanumerico y Geografico |  | 1d | 2014-02-17 | 2014-02-17 | 43 | 79d | 0d | Analistas SIG | 8h | 2,123,960.7 | 1 día | vie 07/02/14 | vie 07/02/14 |
| 45 | 3.1.1.4 | Generar analisis de cruce de información |  | 1d | 2014-02-18 | 2014-02-18 | 44 | 79d | 8d | Analistas SIG | 8h | 2,123,960.7 | 1 día | vie 07/02/14 | vie 07/02/14 |
| 46 | 3.1.2 | **Análisis y diagnóstico de San Marcos (Sucre)** |  | 6d | 2014-02-15 | 2014-02-21 |  | 71d |  |  | 24h | 6,371,882.1 | 2 días | lun 10/02/14 | sáb 08/02/14 |
| 47 | 3.1.2.1 | Generar diagnostico de informacion alfanumerica (Catastro y Registro) |  | 3d | 2014-02-15 | 2014-02-18 | 42 | 71d | 0d |  |  |  |  |  |  |
| 48 | 3.1.2.2 | Generar diagnóstico de capas (Geodatabase) |  | 1d | 2014-02-19 | 2014-02-19 | 47 | 76d | 0d | Analistas SIG | 8h | 2,123,960.7 |  |  |  |
| 49 | 3.1.2.3 | Generar cruce alfanumerico y Geografico |  | 1d | 2014-02-20 | 2014-02-20 | 48 | 76d | 0d | Analistas SIG | 8h | 2,123,960.7 |  |  |  |
| 50 | 3.1.2.4 | Generar analisis de cruce de información |  | 1d | 2014-02-21 | 2014-02-21 | 49 | 76d | 5d | Analistas SIG | 8h | 2,123,960.7 |  |  |  |
| 51 | 3.1.3 | **Análisis y diagnóstico de Caimito (Sucre)** |  | 4d | 2014-02-19 | 2014-02-22 |  | 71d |  |  | 24h | 6,371,882.1 | 1 día | mar 11/02/14 | mar 11/02/14 |
| 52 | 3.1.3.1 | Generar diagnostico de informacion alfanumerica (Catastro y Registro) |  | 1d | 2014-02-19 | 2014-02-19 | 47 | 71d | 0d |  |  |  |  |  |  |
| 53 | 3.1.3.2 | Generar diagnóstico de capas (Geodatabase) |  | 1d | 2014-02-20 | 2014-02-20 | 52 | 75d | 0d | Analistas SIG | 8h | 2,123,960.7 | 1 día | mar 11/02/14 | mar 11/02/14 |
| 54 | 3.1.3.3 | Generar cruce alfanumerico y Geografico |  | 1d | 2014-02-21 | 2014-02-21 | 53 | 75d | 0d | Analistas SIG | 8h | 2,123,960.7 | 1 día | mar 11/02/14 | mar 11/02/14 |
| 55 | 3.1.3.4 | Generar analisis de cruce de información |  | 1d | 2014-02-22 | 2014-02-22 | 54 | 75d | 4d | Analistas SIG | 8h | 2,123,960.7 | 1 día | mar 11/02/14 | mar 11/02/14 |

Notes:
- 38: Entregable 2 / La base de datos geográfica con información predial que incluya el tipo de tenencia, la identificación del predio, el nombre del propietario (s) actual (es), la relación jurídico-catastral, el área registrada según folio, el área registrada según catastro, la nomenclatura o identificación del predio, y las afectaciones jurídicas, entre otras.

| ID | WBS | Task | Duration | Start | Finish | Predecessors | Total slack | Free slack | Resources | Work | Cost | Text27 | Text29 | Text30 |
| --- | --- | --- | --- | --- | --- | --- | --- | --- | --- | --- | --- | --- | --- | --- |
| 56 | 3.1.4 | **Análisis y diagnóstico de San Benito Abad (Sucre)** | 4d | 2014-02-20 | 2014-02-24 |  | 71d |  |  | 24h | 6,371,882.1 | 2 días | jue 13/02/14 | mié 12/02/14 |
| 57 | 3.1.4.1 | Generar diagnostico de informacion alfanumerica (Catastro y Registro) | 1d | 2014-02-20 | 2014-02-20 | 52 | 71d | 0d |  |  |  |  |  |  |
| 58 | 3.1.4.2 | Generar diagnóstico de capas (Geodatabase) | 1d | 2014-02-21 | 2014-02-21 | 57 | 74d | 0d | Analistas SIG | 8h | 2,123,960.7 | 1 día | mié 12/02/14 | mié 12/02/14 |
| 59 | 3.1.4.3 | Generar cruce alfanumerico y Geografico | 1d | 2014-02-22 | 2014-02-22 | 58 | 74d | 0d | Analistas SIG | 8h | 2,123,960.7 | 1 día | mié 12/02/14 | mié 12/02/14 |
| 60 | 3.1.4.4 | Generar analisis de cruce de información | 1d | 2014-02-24 | 2014-02-24 | 59 | 74d | 3d | Analistas SIG | 8h | 2,123,960.7 | 1 día | jue 13/02/14 | jue 13/02/14 |
| 61 | 3.1.5 | **Análisis y diagnóstico de Ayapel (Córdoba)** | 6d | 2014-02-21 | 2014-02-27 |  | 71d |  |  | 24h | 6,371,882.1 | 1 día | vie 14/02/14 | vie 14/02/14 |
| 62 | 3.1.5.1 | Generar diagnostico de informacion alfanumerica (Catastro y Registro) | 3d | 2014-02-21 | 2014-02-24 | 57 | 71d | 0d |  |  |  |  |  |  |
| 63 | 3.1.5.2 | Generar diagnóstico de capas (Geodatabase) | 1d | 2014-02-25 | 2014-02-25 | 62 | 71d | 0d | Analistas SIG | 8h | 2,123,960.7 | 1 día | vie 14/02/14 | vie 14/02/14 |
| 64 | 3.1.5.3 | Generar cruce alfanumerico y Geografico | 1d | 2014-02-26 | 2014-02-26 | 63 | 71d | 0d | Analistas SIG | 8h | 2,123,960.7 | 1 día | vie 14/02/14 | vie 14/02/14 |
| 65 | 3.1.5.4 | Generar analisis de cruce de información | 1d | 2014-02-27 | 2014-02-27 | 64 | 71d | 0d | Analistas SIG | 8h | 2,123,960.7 | 1 día | vie 14/02/14 | vie 14/02/14 |
| 66 | 3.1.6 | **Análisis y diagnóstico de Nechi (Antioquia)** | 4d | 2014-02-12 | 2014-02-15 |  | 76d |  |  | 24h | 6,371,882.1 | 1 día | sáb 15/02/14 | sáb 15/02/14 |
| 67 | 3.1.6.1 | Generar diagnostico de informacion alfanumerica (Catastro y Registro) | 1d | 2014-02-12 | 2014-02-12 | 38 | 76d | 0d |  |  |  |  |  |  |
| 68 | 3.1.6.2 | Generar diagnóstico de capas (Geodatabase) | 1d | 2014-02-13 | 2014-02-13 | 67 | 81d | 0d | Analistas SIG | 8h | 2,123,960.7 | 1 día | sáb 15/02/14 | sáb 15/02/14 |
| 69 | 3.1.6.3 | Generar cruce alfanumerico y Geografico | 1d | 2014-02-14 | 2014-02-14 | 68 | 81d | 0d | Analistas SIG | 8h | 2,123,960.7 | 1 día | sáb 15/02/14 | sáb 15/02/14 |
| 70 | 3.1.6.4 | Generar analisis de cruce de información | 1d | 2014-02-15 | 2014-02-15 | 69 | 81d | 10d | Analistas SIG | 8h | 2,123,960.7 | 1 día | sáb 15/02/14 | sáb 15/02/14 |
| 71 | 3.1.7 | **Análisis y diagnóstico de San Jacinto Del Cauca (Bolívar)** | 4d | 2014-02-13 | 2014-02-17 |  | 76d |  |  | 24h | 6,371,882.1 | 1 día | lun 17/02/14 | lun 17/02/14 |
| 72 | 3.1.7.1 | Generar diagnostico de informacion alfanumerica (Catastro y Registro) | 1d | 2014-02-13 | 2014-02-13 | 67 | 76d | 0d |  |  |  |  |  |  |
| 73 | 3.1.7.2 | Generar diagnóstico de capas (Geodatabase) | 1d | 2014-02-14 | 2014-02-14 | 72 | 80d | 0d | Analistas SIG | 8h | 2,123,960.7 | 1 día | lun 17/02/14 | lun 17/02/14 |
| 74 | 3.1.7.3 | Generar cruce alfanumerico y Geografico | 1d | 2014-02-15 | 2014-02-15 | 73 | 80d | 0d | Analistas SIG | 8h | 2,123,960.7 | 1 día | lun 17/02/14 | lun 17/02/14 |
| 75 | 3.1.7.4 | Generar analisis de cruce de información | 1d | 2014-02-17 | 2014-02-17 | 74 | 80d | 9d | Analistas SIG | 8h | 2,123,960.7 | 1 día | lun 17/02/14 | lun 17/02/14 |
| 76 | 3.1.8 | **Análisis y diagnóstico de Guaranda (Sucre)** | 4d | 2014-02-14 | 2014-02-18 |  | 76d |  |  | 24h | 6,371,882.1 | 1 día | mar 18/02/14 | mar 18/02/14 |
| 77 | 3.1.8.1 | Generar diagnostico de informacion alfanumerica (Catastro y Registro) | 1d | 2014-02-14 | 2014-02-14 | 72 | 76d | 0d |  |  |  |  |  |  |
| 78 | 3.1.8.2 | Generar diagnóstico de capas (Geodatabase) | 1d | 2014-02-15 | 2014-02-15 | 77 | 79d | 0d | Analistas SIG | 8h | 2,123,960.7 | 1 día | mar 18/02/14 | mar 18/02/14 |
| 79 | 3.1.8.3 | Generar cruce alfanumerico y Geografico | 1d | 2014-02-17 | 2014-02-17 | 78 | 79d | 0d | Analistas SIG | 8h | 2,123,960.7 | 1 día | mar 18/02/14 | mar 18/02/14 |
| 80 | 3.1.8.4 | Generar analisis de cruce de información | 1d | 2014-02-18 | 2014-02-18 | 79 | 79d | 8d | Analistas SIG | 8h | 2,123,960.7 | 1 día | mar 18/02/14 | mar 18/02/14 |

| ID | WBS | Task | Type | Duration | Start | Finish | Predecessors | Total slack | Free slack | Resources | Work | Cost | Text27 | Text29 | Text30 |
| --- | --- | --- | --- | --- | --- | --- | --- | --- | --- | --- | --- | --- | --- | --- | --- |
| 81 | 3.1.9 | **Análisis y diagnóstico de Majagual (Sucre)** |  | 4d | 2014-02-15 | 2014-02-19 |  | 76d |  |  | 24h | 6,371,882.1 | 1 día | mié 19/02/14 | mié 19/02/14 |
| 82 | 3.1.9.1 | Generar diagnostico de informacion alfanumerica (Catastro y Registro) |  | 1d | 2014-02-15 | 2014-02-15 | 77 | 76d | 0d |  |  |  |  |  |  |
| 83 | 3.1.9.2 | Generar diagnóstico de capas (Geodatabase) |  | 1d | 2014-02-17 | 2014-02-17 | 82 | 78d | 0d | Analistas SIG | 8h | 2,123,960.7 | 1 día | mié 19/02/14 | mié 19/02/14 |
| 84 | 3.1.9.3 | Generar cruce alfanumerico y Geografico |  | 1d | 2014-02-18 | 2014-02-18 | 83 | 78d | 0d | Analistas SIG | 8h | 2,123,960.7 | 1 día | mié 19/02/14 | mié 19/02/14 |
| 85 | 3.1.9.4 | Generar analisis de cruce de información |  | 1d | 2014-02-19 | 2014-02-19 | 84 | 78d | 7d | Analistas SIG | 8h | 2,123,960.7 | 1 día | mié 19/02/14 | mié 19/02/14 |
| 86 | 3.1.10 | **Análisis y diagnóstico de Achí (Bolívar)** |  | 4d | 2014-02-17 | 2014-02-20 |  | 76d |  |  | 24h | 6,371,882.1 | 1 día | jue 20/02/14 | jue 20/02/14 |
| 87 | 3.1.10.1 | Generar diagnostico de informacion alfanumerica (Catastro y Registro) |  | 1d | 2014-02-17 | 2014-02-17 | 82 | 76d | 0d |  |  |  |  |  |  |
| 88 | 3.1.10.2 | Generar diagnóstico de capas (Geodatabase) |  | 1d | 2014-02-18 | 2014-02-18 | 87 | 77d | 0d | Analistas SIG | 8h | 2,123,960.7 | 1 día | jue 20/02/14 | jue 20/02/14 |
| 89 | 3.1.10.3 | Generar cruce alfanumerico y Geografico |  | 1d | 2014-02-19 | 2014-02-19 | 88 | 77d | 0d | Analistas SIG | 8h | 2,123,960.7 | 1 día | jue 20/02/14 | jue 20/02/14 |
| 90 | 3.1.10.4 | Generar analisis de cruce de información |  | 1d | 2014-02-20 | 2014-02-20 | 89 | 77d | 6d | Analistas SIG | 8h | 2,123,960.7 | 1 día | jue 20/02/14 | jue 20/02/14 |
| 91 | 3.1.11 | **Análisis y diagnóstico de Sucre (Sucre)** |  | 4d | 2014-02-18 | 2014-02-21 |  | 76d |  |  | 24h | 6,371,882.1 | 1 día | vie 21/02/14 | vie 21/02/14 |
| 92 | 3.1.11.1 | Generar diagnostico de informacion alfanumerica (Catastro y Registro) |  | 1d | 2014-02-18 | 2014-02-18 | 87 | 76d | 0d |  |  |  |  |  |  |
| 93 | 3.1.11.2 | Generar diagnóstico de capas (Geodatabase) |  | 1d | 2014-02-19 | 2014-02-19 | 92 | 76d | 0d | Analistas SIG | 8h | 2,123,960.7 | 1 día | vie 21/02/14 | vie 21/02/14 |
| 94 | 3.1.11.3 | Generar cruce alfanumerico y Geografico |  | 1d | 2014-02-20 | 2014-02-20 | 93 | 76d | 0d | Analistas SIG | 8h | 2,123,960.7 | 1 día | vie 21/02/14 | vie 21/02/14 |
| 95 | 3.1.11.4 | Generar analisis de cruce de información |  | 1d | 2014-02-21 | 2014-02-21 | 94 | 76d | 5d | Analistas SIG | 8h | 2,123,960.7 | 1 día | vie 21/02/14 | vie 21/02/14 |
| 96 | 3.2 | **Diagnóstico de Información POT, EOT, PBOT** |  | 13d | 2014-02-12 | 2014-02-26 |  | 21d |  |  | 547.2h | 38,231,292.51 | 11 días | lun 17/02/14 | mié 05/02/14 |
| 97 | 3.2.1 | Revisar documentos POT, EOT, PBOT |  | 13d | 2014-02-12 | 2014-02-26 | 38 | 21d | 0d | Perito Avaluador [300%]; Coordinador de Información [5%]; Analistas SIG [20%] | 480h | 25,487,528.34 | 10 días | sáb 15/02/14 | mié 05/02/14 |
| 98 | 3.2.2 | Verificar capas geográficas de POT, EOT, PBOT |  | 13d | 2014-02-12 | 2014-02-26 | 97SS | 108d |  | Experto SIG [20%]; Analistas SIG | 32h | 4,247,921.39 | 3 días | mar 04/02/14 | sáb 01/02/14 |
| 99 | 3.2.3 | Generar informe de diagnóstico de POT, EOT, PBOT |  | 13d | 2014-02-12 | 2014-02-26 | 97SS | 21d | 0d | Coordinador de Información [10%]; Auxiliar Administrativo [10%] | 35.2h | 8,495,842.78 | 5 días | lun 17/02/14 | mié 12/02/14 |
| 100 | 3.2.4 | Informe de diagnóstico de POT, EOT, PBOT generado | milestone | 0d | 2014-02-26 | 2014-02-26 | 99 | 21d | 0d |  |  |  | 0 días | lun 17/02/14 | lun 17/02/14 |
| 101 | 3.3 | **Análisis final de información** |  | 6d | 2014-02-28 | 2014-03-06 |  | 71d |  |  | 85.6h | 21,239,606.96 | 9 días | sáb 22/02/14 | jue 13/02/14 |
| 102 | 3.3.1 | Generar análisis final de resultado de cruces |  | 4d | 2014-02-28 | 2014-03-04 | 45, 50, 55, 60, 65, 70, 75, 80, 85, 90, 95 | 71d | 0d | Analistas de Información | 40h | 10,619,803.48 | 4 días | mié 19/02/14 | sáb 15/02/14 |
| 103 | 3.3.2 | Generar Informe final de análisis |  | 3d | 2014-03-04 | 2014-03-06 | 102FS-1d | 71d | 0d | Analistas de Información [20%]; Auxiliar Administrativo [20%] | 28.8h | 6,371,882.09 | 3 días | vie 21/02/14 | mié 19/02/14 |
| 104 | 3.3.3 | Generar capa final de predios para selección de muestra |  | 3d | 2014-03-04 | 2014-03-06 | 103SS | 101d |  | Experto SIG [5%]; Analistas SIG [5%] | 16.8h | 4,247,921.39 | 1 día | sáb 22/02/14 | sáb 22/02/14 |
| 105 | 3.3.4 | Informe final de cruce generado | milestone | 0d | 2014-03-06 | 2014-03-06 | 103 | 71d | 0d |  |  |  | 0 días | sáb 22/02/14 | sáb 22/02/14 |
| 106 | 3.4 | Documento de análisis y diagnóstico (Entregable 3) generado | milestone | 0d | 2014-03-07 | 2014-03-07 | 100, 105FS+1d | 91d | 0d |  |  |  | 0 días | mar 25/02/14 | mar 25/02/14 |

Notes:
- 106: Entregable 3 / El documento con el análisis de la información, el diagnóstico, las inconsistencias encontradas y recomendaciones para el Fondo, del manejo del cruce entre los datos de registro y catastro.

| ID | WBS | Task | Type | Duration | Start | Finish | Predecessors | Total slack | Free slack | Resources | Work | Cost | Text27 | Text29 | Text30 |
| --- | --- | --- | --- | --- | --- | --- | --- | --- | --- | --- | --- | --- | --- | --- | --- |
| 107 | 4 | **Fase de actualización de información** |  | 14d | 2014-02-26 | 2014-03-14 |  | 30d |  |  | 132h | 44,603,174.65 | 23 días | mar 04/03/14 | mié 05/02/14 |
| 108 | 4.1 | **Recepción de Información complementaria del FONDO** |  | 5d | 2014-02-26 | 2014-03-04 |  | 30d |  |  | 4h | 2,123,960.7 | 5 días | mar 11/02/14 | mié 05/02/14 |
| 109 | 4.1.1 | Entregar DTM (Pendientes) | milestone | 0d | 2014-02-26 | 2014-02-26 | 100 | 30d | 0d |  |  | 2,123,960.7 | 0 días | mié 05/02/14 | mié 05/02/14 |
| 110 | 4.1.2 | Validar información DTM |  | 5d | 2014-02-27 | 2014-03-04 | 109 | 103d | 0d | Coordinador de Información [10%]; Analistas SIG [20%] | 4h |  | 5 días | mar 11/02/14 | jue 06/02/14 |
| 111 | 4.2 | **Actualización de información** |  | 10d | 2014-03-04 | 2014-03-14 |  | 94d |  |  | 128h | 42,479,213.95 | 19 días | mar 04/03/14 | mar 11/02/14 |
| 112 | 4.2.1 | Actualizar Información temática (DTM - pendientes) |  | 1d | 2014-03-04 | 2014-03-04 | 110FS-1d | 103d |  | Supervisor FONDO | 8h | 10,619,803.48 | 1 día | mar 11/02/14 | mar 11/02/14 |
| 113 | 4.2.2 | **Actualización de información cartográfica y temática de municipios (POT, EOT, PBOT)** |  | 7d | 2014-03-07 | 2014-03-14 |  | 94d |  |  | 120h | 31,859,410.47 | 7 días | mar 04/03/14 | mar 25/02/14 |
| 114 | 4.2.2.1 | Actualizar Magangué (Bolívar) |  | 2d | 2014-03-07 | 2014-03-08 | 106FS-1d | 98d | 0d | Analistas SIG | 16h | 4,247,921.39 | 2 días | mié 26/02/14 | mar 25/02/14 |
| 115 | 4.2.2.2 | Actualizar San Marcos (Sucre) |  | 1d | 2014-03-10 | 2014-03-10 | 114 | 95d | 0d | Analistas SIG | 8h | 2,123,960.7 | 1 día | jue 27/02/14 | jue 27/02/14 |
| 116 | 4.2.2.3 | Actualizar Caimito (Sucre) |  | 1d | 2014-03-11 | 2014-03-11 | 115 | 95d | 0d | Analistas SIG | 8h | 2,123,960.7 | 1 día | vie 28/02/14 | vie 28/02/14 |
| 117 | 4.2.2.4 | Actualizar San Benito Abad (Sucre) |  | 1d | 2014-03-12 | 2014-03-12 | 116 | 95d | 0d | Analistas SIG | 8h | 2,123,960.7 | 1 día | sáb 01/03/14 | sáb 01/03/14 |
| 118 | 4.2.2.5 | Actualizar Ayapel (Córdoba) |  | 2d | 2014-03-12 | 2014-03-13 | 117SS | 98d | 1d | Analistas SIG | 24h | 6,371,882.09 | 2 días | lun 03/03/14 | sáb 01/03/14 |
| 119 | 4.2.2.6 | Actualizar Nechi (Antioquia) |  | 1d | 2014-03-07 | 2014-03-07 | 106FS-1d | 97d | 0d | Analistas SIG | 8h | 2,123,960.7 | 1 día | mar 25/02/14 | mar 25/02/14 |
| 120 | 4.2.2.7 | Actualizar San Jacinto del Cauca (Bolívar) |  | 1d | 2014-03-08 | 2014-03-08 | 119 | 94d | 0d | Analistas SIG | 8h | 2,123,960.7 | 1 día | mié 26/02/14 | mié 26/02/14 |
| 121 | 4.2.2.8 | Actualizar Guaranda (Sucre) |  | 1d | 2014-03-10 | 2014-03-10 | 120 | 94d | 0d | Analistas SIG | 8h | 2,123,960.7 | 1 día | jue 27/02/14 | jue 27/02/14 |
| 122 | 4.2.2.9 | Actualizar Majagual (Sucre) |  | 1d | 2014-03-11 | 2014-03-11 | 121 | 94d | 0d | Analistas SIG | 8h | 2,123,960.7 | 1 día | vie 28/02/14 | vie 28/02/14 |
| 123 | 4.2.2.10 | Actualizar Achí (Bolívar) |  | 2d | 2014-03-12 | 2014-03-13 | 122 | 94d | 0d | Analistas SIG | 16h | 4,247,921.39 | 2 días | lun 03/03/14 | sáb 01/03/14 |
| 124 | 4.2.2.11 | Actualizar Sucre (Sucre) |  | 1d | 2014-03-14 | 2014-03-14 | 123 | 94d | 0d | Analistas SIG | 8h | 2,123,960.7 | 1 día | mar 04/03/14 | mar 04/03/14 |
| 125 | 4.2.2.12 | Información cartográfica y temática de la Mojana actualizada | milestone | 0d | 2014-03-14 | 2014-03-14 | 124, 118 | 97d | 0d |  |  |  | 0 días | mar 04/03/14 | mar 04/03/14 |
| 126 | 5 | **Fase de elaboración de Encuestas prediales** |  | 81d | 2014-02-27 | 2014-06-06 |  | 24d |  |  | 9240.8h | 904,807,256.26 | 72 días | sáb 10/05/14 | mié 12/02/14 |
| 127 | 5.1 | **Diseño de encuesta predial** |  | 8d | 2014-03-06 | 2014-03-14 |  | 21d |  |  | 36.4h | 12,743,764.17 | 7 días | mié 19/02/14 | mié 12/02/14 |
| 128 | 5.1.1 | Diseñar encuesta predial |  | 3d | 2014-03-06 | 2014-03-08 | 100FS+6d | 21d | 0d | Director de proyecto [5%]; Experto Social [50%]; Experto Catastral [50%]; Profesional de apoyo sistemas [50%] | 32.8h | 4,247,921.39 | 2 días | jue 13/02/14 | mié 12/02/14 |
| 129 | 5.1.2 | Radicar encuesta diseñada para aprobación del FONDO |  | 1d | 2014-03-10 | 2014-03-10 | 128 | 29d | 0d | Director de proyecto [5%]; Auxiliar Administrativo [20%] | 2h |  | 1 día | vie 14/02/14 | vie 14/02/14 |
| 130 | 5.1.3 | Revisar contenido y forma de encuesta predial (FONDO) |  | 4d | 2014-03-11 | 2014-03-14 | 129 | 29d | 0d | Supervisor FONDO [5%] | 1.6h | 8,495,842.78 | 4 días | mié 19/02/14 | sáb 15/02/14 |
| 131 | 5.1.4 | Ficha predial aprobada (FONDO) | milestone | 0d | 2014-03-14 | 2014-03-14 | 130 | 29d | 0d |  |  |  | 0 días | mié 19/02/14 | mié 19/02/14 |

| ID | WBS | Task | Type | Duration | Start | Finish | Predecessors | Total slack | Free slack | Resources | Work | Cost | Text27 | Text29 | Text30 |
| --- | --- | --- | --- | --- | --- | --- | --- | --- | --- | --- | --- | --- | --- | --- | --- |
| 132 | 5.2 | **Definición de plan de divulgación** |  | 10d | 2014-02-27 | 2014-03-10 |  | 24d |  |  | 16h | 12,743,764.18 | 5 días | lun 17/02/14 | mié 12/02/14 |
| 133 | 5.2.1 | Definir plan de divulgación |  | 6d | 2014-02-27 | 2014-03-05 | 100 | 24d | 0d | Director de proyecto [10%]; Experto Social [30%]; Gerente de Operaciones [30%] | 5.6h | 2,123,960.7 | 1 día | mié 12/02/14 | mié 12/02/14 |
| 134 | 5.2.2 | Radicar plan de divulgación |  | 1d | 2014-03-06 | 2014-03-06 | 133 | 24d | 0d | Director de proyecto [10%]; Auxiliar Administrativo [10%] | 8.8h | 2,123,960.7 | 1 día | jue 13/02/14 | jue 13/02/14 |
| 135 | 5.2.3 | Revisar plan de divulgación (FONDO) |  | 4d | 2014-03-06 | 2014-03-10 | 134SS | 24d | 0d | Supervisor FONDO [5%] | 1.6h | 8,495,842.78 | 4 días | lun 17/02/14 | jue 13/02/14 |
| 136 | 5.2.4 | Plan de divulgación aprobado (FONDO) | milestone | 0d | 2014-03-10 | 2014-03-10 | 135 | 24d | 0d |  |  |  | 0 días | lun 17/02/14 | lun 17/02/14 |
| 137 | 5.3 | **Ejecución de plan de divulgación** |  | 18d | 2014-03-14 | 2014-04-04 |  | 29d |  |  | 448h | 59,470,899.48 | 9 días | mié 26/02/14 | lun 17/02/14 |
| 138 | 5.3.1 | Socializar Magangué |  | 5d | 2014-03-28 | 2014-04-02 | 136FS+14d | 31d | 5d | Experto Social; Conductor | 80h | 10,619,803.48 | 5 días | vie 21/02/14 | lun 17/02/14 |
| 139 | 5.3.2 | Socializar San Marcos / Caimito / San Benito |  | 7d | 2014-03-28 | 2014-04-04 | 136FS+14d | 24d | 3d | Experto Jurídico; Conductor | 112h | 14,867,724.87 | 7 días | lun 24/02/14 | lun 17/02/14 |
| 140 | 5.3.3 | Socializar Ayapel / Nechí / San Jacinto del Cauca |  | 7d | 2014-03-20 | 2014-03-28 | 136FS+8d | 29d | 6d | Experto Catastral; Conductor | 112h | 14,867,724.87 | 7 días | lun 24/02/14 | lun 17/02/14 |
| 141 | 5.3.4 | Socializar Guaranda / Majagual / Achí / Sucre |  | 9d | 2014-03-14 | 2014-03-25 | 136FS+3d | 38d | 14d | Perito Avaluador; Conductor | 144h | 19,115,646.26 | 9 días | mié 26/02/14 | lun 17/02/14 |
| 142 | 5.4 | **Caracterización de predios** |  | 27d | 2014-03-15 | 2014-04-16 |  | 21d |  |  | 2312.8h | 271,866,969.03 | 32 días | jue 20/03/14 | mié 12/02/14 |
| 143 | 5.4.1 | Verificación de características de los predios |  | 3d | 2014-03-15 | 2014-03-18 | 38FS+5d, 109FS+5d, 128FS+5d | 21d | 0d | Director de proyecto [10%]; Experto Catastral [10%]; Perito Avaluador [10%]; Experto Social [20%]; Analistas SIG [20%] | 79.2h | 6,371,882.09 | 3 días | vie 14/02/14 | mié 12/02/14 |
| 144 | 5.4.2 | Analizar distribución según características |  | 4d | 2014-03-19 | 2014-03-22 | 143 | 21d | 0d | Coordinador de Información [20%]; Analistas SIG [200%] | 35.2h | 4,247,921.39 | 4 días | mar 25/02/14 | vie 21/02/14 |
| 145 | 5.4.3 | **Caracterización para desplazamiento por municipio** |  | 20d | 2014-03-25 | 2014-04-16 |  | 21d |  |  | 1776h | 235,759,637.21 | 20 días | jue 20/03/14 | mié 26/02/14 |
| 146 | 5.4.3.1 | **Magangué (Bolívar)** |  | 11d | 2014-03-25 | 2014-04-05 |  | 26d |  |  | 160h | 21,239,606.96 | 11 días | lun 10/03/14 | mié 26/02/14 |
| 147 | 5.4.3.1.1 | Caracterizar Magangué Urbano |  | 5d | 2014-03-25 | 2014-03-29 | 144 | 26d | 0d | Perito Avaluador; Técnicos de campo | 80h | 10,619,803.48 | 5 días | lun 03/03/14 | mié 26/02/14 |
| 148 | 5.4.3.1.2 | Caracterizar Magangué Rural |  | 5d | 2014-04-01 | 2014-04-05 | 147FS+1d | 26d | 0d | Perito Avaluador; Técnicos de campo | 80h | 10,619,803.48 | 5 días | lun 10/03/14 | mié 05/03/14 |
| 149 | 5.4.3.2 | **San Marcos (Sucre)** |  | 11d | 2014-03-25 | 2014-04-05 |  | 21d |  |  | 176h | 23,363,567.65 | 11 días | lun 10/03/14 | mié 26/02/14 |
| 150 | 5.4.3.2.1 | Caracterizar San Marcos Urbano |  | 4d | 2014-03-25 | 2014-03-28 | 144 | 21d | 0d | Perito Avaluador; Técnicos de campo | 64h | 8,495,842.78 | 4 días | sáb 01/03/14 | mié 26/02/14 |
| 151 | 5.4.3.2.2 | Caracterizar San Marcos Rural |  | 7d | 2014-03-29 | 2014-04-05 | 150 | 21d | 0d | Perito Avaluador; Técnicos de campo | 112h | 14,867,724.87 | 7 días | lun 10/03/14 | lun 03/03/14 |
| 152 | 5.4.3.3 | **Caimito (Sucre)** |  | 11d | 2014-03-25 | 2014-04-05 |  | 43d |  |  | 176h | 23,363,567.65 | 11 días | lun 10/03/14 | mié 26/02/14 |
| 153 | 5.4.3.3.1 | Caracterizar Caimito Urbano |  | 3d | 2014-03-25 | 2014-03-27 | 144 | 43d | 0d | Perito Avaluador; Técnicos de campo | 48h | 6,371,882.09 | 3 días | vie 28/02/14 | mié 26/02/14 |
| 154 | 5.4.3.3.2 | Caracterizar Caimito Rural |  | 8d | 2014-03-28 | 2014-04-05 | 153 | 43d | 0d | Perito Avaluador; Técnicos de campo | 128h | 16,991,685.56 | 8 días | lun 10/03/14 | sáb 01/03/14 |
| 155 | 5.4.3.4 | **San Benito Abad (Sucre)** |  | 8d | 2014-03-25 | 2014-04-02 |  | 43d |  |  | 128h | 16,991,685.57 | 8 días | jue 06/03/14 | mié 26/02/14 |
| 156 | 5.4.3.4.1 | Caracterizar San Benito Urbano |  | 3d | 2014-03-25 | 2014-03-27 | 144 | 43d | 0d | Perito Avaluador; Técnicos de campo | 48h | 6,371,882.09 | 3 días | vie 28/02/14 | mié 26/02/14 |
| 157 | 5.4.3.4.2 | Caracterizar San Benito Rural |  | 5d | 2014-03-28 | 2014-04-02 | 156 | 43d | 0d | Perito Avaluador; Técnicos de campo | 80h | 10,619,803.48 | 5 días | jue 06/03/14 | sáb 01/03/14 |

| ID | WBS | Task | Type | Duration | Start | Finish | Predecessors | Total slack | Free slack | Resources | Work | Cost | Text27 | Text29 | Text30 |
| --- | --- | --- | --- | --- | --- | --- | --- | --- | --- | --- | --- | --- | --- | --- | --- |
| 158 | 5.4.3.5 | **Ayapel (Córdoba)** |  | 8d | 2014-03-25 | 2014-04-02 |  | 23d |  |  | 112h | 14,867,724.87 | 8 días | jue 06/03/14 | mié 26/02/14 |
| 159 | 5.4.3.5.1 | CaracterizarAyapel Urbano |  | 2d | 2014-03-25 | 2014-03-26 | 144 | 23d | 0d | Perito Avaluador; Técnicos de campo | 32h | 4,247,921.39 | 2 días | jue 27/02/14 | mié 26/02/14 |
| 160 | 5.4.3.5.2 | Caracterizar Ayapel Rural |  | 6d | 2014-03-27 | 2014-04-02 | 159 | 23d | 0d | Perito Avaluador; Técnicos de campo | 80h | 10,619,803.48 | 6 días | jue 06/03/14 | vie 28/02/14 |
| 161 | 5.4.3.6 | **Nechi (Antioquia)** |  | 11d | 2014-04-03 | 2014-04-15 |  | 28d |  |  | 176h | 23,363,567.65 | 11 días | mié 19/03/14 | vie 07/03/14 |
| 162 | 5.4.3.6.1 | Caracterizar Nechí Urbano |  | 5d | 2014-04-03 | 2014-04-08 | 160 | 28d | 0d | Perito Avaluador; Técnicos de campo | 80h | 10,619,803.48 | 5 días | mié 12/03/14 | vie 07/03/14 |
| 163 | 5.4.3.6.2 | Caracterizar Nechí Rural |  | 6d | 2014-04-09 | 2014-04-15 | 162 | 28d | 0d | Perito Avaluador; Técnicos de campo | 96h | 12,743,764.17 | 6 días | mié 19/03/14 | jue 13/03/14 |
| 164 | 5.4.3.7 | **San Jacinto Del Cauca (Bolívar)** |  | 13d | 2014-03-25 | 2014-04-08 |  | 39d |  |  | 208h | 27,611,489.04 | 13 días | mié 12/03/14 | mié 26/02/14 |
| 165 | 5.4.3.7.1 | Caracterizar San Jacinto Urbano |  | 4d | 2014-03-25 | 2014-03-28 | 144 | 39d | 0d | Perito Avaluador; Técnicos de campo | 64h | 8,495,842.78 | 4 días | sáb 01/03/14 | mié 26/02/14 |
| 166 | 5.4.3.7.2 | Caracterizar San Jacinto Rural |  | 9d | 2014-03-29 | 2014-04-08 | 165 | 39d | 0d | Perito Avaluador; Técnicos de campo | 144h | 19,115,646.26 | 9 días | mié 12/03/14 | lun 03/03/14 |
| 167 | 5.4.3.8 | **Guaranda (Sucre)** |  | 13d | 2014-03-25 | 2014-04-08 |  | 24d |  |  | 208h | 27,611,489.04 | 13 días | mié 12/03/14 | mié 26/02/14 |
| 168 | 5.4.3.8.1 | Caracterizar Guaranda Urbano |  | 4d | 2014-03-25 | 2014-03-28 | 144 | 24d | 0d | Perito Avaluador; Técnicos de campo | 64h | 8,495,842.78 | 4 días | sáb 01/03/14 | mié 26/02/14 |
| 169 | 5.4.3.8.2 | Caracterizar Guaranda Rural |  | 9d | 2014-03-29 | 2014-04-08 | 168 | 24d | 0d | Perito Avaluador; Técnicos de campo | 144h | 19,115,646.26 | 9 días | mié 12/03/14 | lun 03/03/14 |
| 170 | 5.4.3.9 | **Majagual (Sucre)** |  | 10d | 2014-03-25 | 2014-04-04 |  | 28d |  |  | 160h | 21,239,606.95 | 10 días | sáb 08/03/14 | mié 26/02/14 |
| 171 | 5.4.3.9.1 | Caracterizar Majagual Urbano |  | 4d | 2014-03-25 | 2014-03-28 | 144 | 28d | 0d | Perito Avaluador; Técnicos de campo | 64h | 8,495,842.78 | 4 días | sáb 01/03/14 | mié 26/02/14 |
| 172 | 5.4.3.9.2 | Caracterizar Majagual Rural |  | 6d | 2014-03-29 | 2014-04-04 | 171 | 28d | 0d | Perito Avaluador; Técnicos de campo | 96h | 12,743,764.17 | 6 días | sáb 08/03/14 | lun 03/03/14 |
| 173 | 5.4.3.10 | **Achí (Bolívar)** |  | 10d | 2014-04-05 | 2014-04-16 |  | 28d |  |  | 160h | 21,239,606.96 | 10 días | jue 20/03/14 | lun 10/03/14 |
| 174 | 5.4.3.10.1 | Caracterizar Achí Urbano |  | 5d | 2014-04-05 | 2014-04-10 | 172 | 28d | 0d | Perito Avaluador; Técnicos de campo | 80h | 10,619,803.48 | 5 días | vie 14/03/14 | lun 10/03/14 |
| 175 | 5.4.3.10.2 | Caracterizar Achí Rural |  | 5d | 2014-04-11 | 2014-04-16 | 174 | 28d | 0d | Perito Avaluador; Técnicos de campo | 80h | 10,619,803.48 | 5 días | jue 20/03/14 | sáb 15/03/14 |
| 176 | 5.4.3.11 | **Sucre (Sucre)** |  | 7d | 2014-03-25 | 2014-04-01 |  | 47d |  |  | 112h | 14,867,724.87 | 7 días | mié 05/03/14 | mié 26/02/14 |
| 177 | 5.4.3.11.1 | Caracterizar Sucre Urbano |  | 2d | 2014-03-25 | 2014-03-26 | 144 | 47d | 0d | Perito Avaluador; Técnicos de campo | 32h | 4,247,921.39 | 2 días | jue 27/02/14 | mié 26/02/14 |
| 178 | 5.4.3.11.2 | Caracterizar Sucre Rural |  | 5d | 2014-03-27 | 2014-04-01 | 177 | 47d | 0d | Perito Avaluador; Técnicos de campo | 80h | 10,619,803.48 | 5 días | mié 05/03/14 | vie 28/02/14 |
| 179 | 5.4.4 | Generar documento y mapa de caracterización |  | 15d | 2014-03-31 | 2014-04-16 | 147 | 67d | 0d | Director de proyecto [10%]; Experto Catastral [10%]; Perito Avaluador [200%]; Experto Social [20%]; Analistas SIG [20%]; Coordinador de Información [10%] | 422.4h | 25,487,528.34 | 15 días | jue 20/03/14 | mar 04/03/14 |
| 180 | 5.4.5 | Documento y mapa de caracterización generado | milestone | 0d | 2014-04-16 | 2014-04-16 | 179 | 67d | 0d |  |  |  | 0 días | jue 20/03/14 | jue 20/03/14 |
| 181 | 5.5 | **Definición de parámetros de selección de predios** |  | 5d | 2014-03-20 | 2014-03-26 |  | 29d |  |  | 70.4h | 8,495,842.78 | 4 días | lun 24/02/14 | jue 20/02/14 |
| 182 | 5.5.1 | Definir parámetros de selección para fichas prediales |  | 3d | 2014-03-20 | 2014-03-22 | 131FS+4d | 29d | 0d | Director de proyecto [10%]; Experto Catastral [10%]; Gerente de Operaciones [20%]; Perito Avaluador [20%]; Experto Social [20%] | 68.8h | 4,247,921.39 | 2 días | vie 21/02/14 | jue 20/02/14 |
| 183 | 5.5.2 | Aprobar parámetros de selección |  | 2d | 2014-03-25 | 2014-03-26 | 182 | 29d | 5d | Supervisor FONDO [10%] | 1.6h | 4,247,921.39 | 2 días | lun 24/02/14 | sáb 22/02/14 |

| ID | WBS | Task | Duration | Start | Finish | Predecessors | Total slack | Free slack | Resources | Work | Cost | Text27 | Text29 | Text30 |
| --- | --- | --- | --- | --- | --- | --- | --- | --- | --- | --- | --- | --- | --- | --- |
| 184 | 5.6 | **Selección de predios** | 15d | 2014-04-02 | 2014-04-21 |  | 24d |  |  | 110.4h | 48,851,095.99 | 15 días | sáb 22/03/14 | jue 06/03/14 |
| 185 | 5.6.1 | Seleccionar predios de Magangué (Bolívar) | 2d | 2014-04-07 | 2014-04-08 | 148, 183 | 26d | 0d | Coordinador de Información [5%]; Experto Social [5%]; Analistas SIG [50%] | 9.6h | 4,247,921.39 | 2 días | mié 12/03/14 | mar 11/03/14 |
| 186 | 5.6.2 | Seleccionar predios de San Marcos (Sucre) | 2d | 2014-04-07 | 2014-04-08 | 151, 183 | 21d | 0d | Coordinador de Información [5%]; Experto Social [5%]; Analistas SIG [50%] | 9.6h | 4,247,921.39 | 2 días | mié 12/03/14 | mar 11/03/14 |
| 187 | 5.6.3 | Seleccionar predios de Caimito (Sucre) | 2d | 2014-04-07 | 2014-04-08 | 154, 183 | 43d | 19d | Coordinador de Información [5%]; Experto Social [5%]; Analistas SIG [50%] | 9.6h | 4,247,921.39 | 2 días | mié 12/03/14 | mar 11/03/14 |
| 188 | 5.6.4 | Seleccionar predios de San Benito Abad (Sucre) | 2d | 2014-04-03 | 2014-04-04 | 157, 183 | 43d | 22d | Coordinador de Información [5%]; Experto Social [5%]; Analistas SIG [50%] | 9.6h | 4,247,921.39 | 2 días | sáb 08/03/14 | vie 07/03/14 |
| 189 | 5.6.5 | Seleccionar predios de Ayapel (Córdoba) | 2d | 2014-04-03 | 2014-04-04 | 160, 183 | 23d | 0d | Coordinador de Información [5%]; Experto Social [5%]; Analistas SIG [50%] | 9.6h | 4,247,921.39 | 2 días | sáb 08/03/14 | vie 07/03/14 |
| 190 | 5.6.6 | Seleccionar predios de Nechi (Antioquia) | 2d | 2014-04-16 | 2014-04-19 | 163, 183 | 28d | 5d | Coordinador de Información [5%]; Experto Social [5%]; Analistas SIG [50%] | 9.6h | 4,247,921.39 | 2 días | vie 21/03/14 | jue 20/03/14 |
| 191 | 5.6.7 | Seleccionar predios de San Jacinto del Cauca (Bolívar) | 2d | 2014-04-09 | 2014-04-10 | 166, 183 | 39d | 11d | Coordinador de Información [5%]; Experto Social [5%]; Analistas SIG [50%] | 9.6h | 4,247,921.39 | 2 días | vie 14/03/14 | jue 13/03/14 |
| 192 | 5.6.8 | Seleccionar predios de Guaranda (Sucre) | 2d | 2014-04-09 | 2014-04-10 | 169, 183 | 24d | 0d | Coordinador de Información [5%]; Experto Social [5%]; Analistas SIG [50%] | 9.6h | 4,247,921.39 | 2 días | vie 14/03/14 | jue 13/03/14 |
| 193 | 5.6.9 | Seleccionar predios de Majagual (Sucre) | 3d | 2014-04-05 | 2014-04-08 | 172, 183 | 38d | 13d | Coordinador de Información [5%]; Experto Social [5%]; Analistas SIG [50%] | 14.4h | 6,371,882.09 | 3 días | mié 12/03/14 | lun 10/03/14 |
| 194 | 5.6.10 | Seleccionar predios de Achí (Bolívar) | 2d | 2014-04-19 | 2014-04-21 | 175, 183 | 28d | 4d | Coordinador de Información [5%]; Experto Social [5%]; Analistas SIG [50%] | 9.6h | 4,247,921.39 | 2 días | sáb 22/03/14 | vie 21/03/14 |
| 195 | 5.6.11 | Seleccionar predios de Sucre (Sucre) | 2d | 2014-04-02 | 2014-04-03 | 178, 183 | 47d | 0d | Coordinador de Información [5%]; Experto Social [5%]; Analistas SIG [50%] | 9.6h | 4,247,921.39 | 2 días | vie 07/03/14 | jue 06/03/14 |
| 196 | 5.7 | **Levantamiento de encuestas prediales** | 43d | 2014-03-27 | 2014-05-19 |  | 27d |  |  | 5427.2h | 356,825,396.81 | 63 días | sáb 10/05/14 | sáb 22/02/14 |
| 197 | 5.7.1 | Generar los planos para desplazamiento | 14d | 2014-04-04 | 2014-04-22 | 195 | 64d |  | Experto SIG [10%]; Experto Catastral [10%]; Perito Avaluador [10%]; Analistas SIG | 145.6h |  | 14 días | mar 25/03/14 | sáb 08/03/14 |
| 198 | 5.7.2 | Capacitar a personal de campo | 4d | 2014-03-27 | 2014-03-31 | 144FS+2d | 27d | 4d | Director de proyecto [10%]; Experto Catastral [10%]; Experto Social [10%]; Técnicos de campo [2400%] | 417.6h | 4,247,921.39 | 2 días | sáb 01/03/14 | vie 28/02/14 |
| 199 | 5.7.3 | **Magangué (Bolívar)** | 27d | 2014-04-09 | 2014-05-13 |  | 26d |  |  | 1344h | 50,975,056.69 | 27 días | lun 14/04/14 | jue 13/03/14 |
| 200 | 5.7.3.1 | **Levantamiento Urbano** | 13d | 2014-04-09 | 2014-04-25 |  | 26d |  |  | 672h | 25,487,528.34 | 13 días | vie 28/03/14 | jue 13/03/14 |
| 201 | 5.7.3.1.1 | Levantar Magangué Urbano Zona 1 | 7d | 2014-04-09 | 2014-04-16 | 185, 138, 198 | 26d | 0d | Técnicos de campo [600%]; Conductor | 336h | 12,743,764.17 | 7 días | jue 20/03/14 | jue 13/03/14 |
| 202 | 5.7.3.1.2 | Levantar Magangué Urbano Zona 2 | 6d | 2014-04-19 | 2014-04-25 | 201 | 26d | 0d | Técnicos de campo [600%]; Conductor | 336h | 12,743,764.17 | 6 días | vie 28/03/14 | vie 21/03/14 |
| 203 | 5.7.3.2 | **Levantamiento Rural** | 14d | 2014-04-26 | 2014-05-13 |  | 26d |  |  | 672h | 25,487,528.35 | 14 días | lun 14/04/14 | sáb 29/03/14 |
| 204 | 5.7.3.2.1 | Levantar Magangué Rural Zona 1 | 7d | 2014-04-26 | 2014-05-05 | 202 | 26d | 0d | Técnicos de campo [600%]; Conductor | 392h | 14,867,724.87 | 7 días | sáb 05/04/14 | sáb 29/03/14 |
| 205 | 5.7.3.2.2 | Levantar Magangué Rural Zona 2 | 5d | 2014-05-08 | 2014-05-13 | 204FS+2d | 26d | 0d | Técnicos de campo [600%]; Conductor | 280h | 10,619,803.48 | 5 días | lun 14/04/14 | mié 09/04/14 |
| 206 | 5.7.4 | **San Marcos (Sucre)** | 19d | 2014-04-09 | 2014-05-03 |  | 21d |  |  | 760h | 40,355,253.21 | 19 días | vie 04/04/14 | jue 13/03/14 |
| 207 | 5.7.4.1 | **Urbano** | 11d | 2014-04-09 | 2014-04-23 |  | 21d |  |  | 440h | 23,363,567.65 | 11 días | mié 26/03/14 | jue 13/03/14 |
| 208 | 5.7.4.1.1 | Levantar San Marcos Urbano Zona 1 | 6d | 2014-04-09 | 2014-04-15 | 186, 139, 198 | 21d | 0d | Técnicos de campo [400%]; Conductor | 240h | 12,743,764.17 | 6 días | mié 19/03/14 | jue 13/03/14 |
| 209 | 5.7.4.1.2 | Levantar San Marcos Urbano Zona 2 | 5d | 2014-04-16 | 2014-04-23 | 208 | 21d | 0d | Técnicos de campo [400%]; Conductor | 200h | 10,619,803.48 | 5 días | mié 26/03/14 | jue 20/03/14 |
| 210 | 5.7.4.2 | Levantar San Marcos Rural | 8d | 2014-04-24 | 2014-05-03 | 209 | 21d | 0d | Técnicos de campo [400%]; Conductor | 320h | 16,991,685.56 | 8 días | vie 04/04/14 | jue 27/03/14 |

| ID | WBS | Task | Duration | Start | Finish | Predecessors | Total slack | Free slack | Resources | Work | Cost | Text27 | Text29 | Text30 |
| --- | --- | --- | --- | --- | --- | --- | --- | --- | --- | --- | --- | --- | --- | --- |
| 211 | 5.7.5 | **Caimito (Sucre)** | 11d | 2014-05-05 | 2014-05-16 |  | 24d |  |  | 176h | 23,363,567.65 | 11 días | sáb 19/04/14 | sáb 05/04/14 |
| 212 | 5.7.5.1 | Levantar Caimito Urbano | 9d | 2014-05-05 | 2014-05-14 | 210, 187, 139 | 24d | 0d | Técnicos de campo; Conductor | 144h | 19,115,646.26 | 9 días | mar 15/04/14 | sáb 05/04/14 |
| 213 | 5.7.5.2 | Levantar Caimito Rural | 2d | 2014-05-15 | 2014-05-16 | 212 | 24d | 0d | Técnicos de campo; Conductor | 32h | 4,247,921.39 | 2 días | sáb 19/04/14 | mié 16/04/14 |
| 214 | 5.7.6 | **San Benito Abad (Sucre)** | 13d | 2014-05-05 | 2014-05-19 |  | 21d |  |  | 208h | 27,611,489.04 | 13 días | mar 22/04/14 | sáb 05/04/14 |
| 215 | 5.7.6.1 | Levantar San Benito Abad Urbano | 10d | 2014-05-05 | 2014-05-15 | 139, 210, 188 | 21d | 0d | Técnicos de campo; Conductor | 160h | 21,239,606.95 | 10 días | mié 16/04/14 | sáb 05/04/14 |
| 216 | 5.7.6.2 | Levantar San Benito Abad Rural | 3d | 2014-05-16 | 2014-05-19 | 215 | 21d | 0d | Técnicos de campo; Conductor | 48h | 6,371,882.09 | 3 días | mar 22/04/14 | sáb 19/04/14 |
| 217 | 5.7.7 | **Ayapel (Córdoba)** | 16d | 2014-04-05 | 2014-04-25 |  | 23d |  |  | 384h | 33,983,371.13 | 16 días | vie 28/03/14 | lun 10/03/14 |
| 218 | 5.7.7.1 | Levantar Ayapel Urbano | 9d | 2014-04-05 | 2014-04-15 | 140, 189, 198 | 23d | 0d | Técnicos de campo [200%]; Conductor | 216h | 19,115,646.26 | 9 días | mié 19/03/14 | lun 10/03/14 |
| 219 | 5.7.7.2 | Levantar Ayapel Rural | 7d | 2014-04-16 | 2014-04-25 | 218 | 23d | 0d | Técnicos de campo [200%]; Conductor | 168h | 14,867,724.87 | 7 días | vie 28/03/14 | jue 20/03/14 |
| 220 | 5.7.8 | **Nechi (Antioquia)** | 16d | 2014-04-26 | 2014-05-15 |  | 23d |  |  | 384h | 33,983,371.12 | 16 días | mié 16/04/14 | sáb 29/03/14 |
| 221 | 5.7.8.1 | **Urbano** | 12d | 2014-04-26 | 2014-05-10 |  | 23d |  |  | 288h | 25,487,528.34 | 12 días | vie 11/04/14 | sáb 29/03/14 |
| 222 | 5.7.8.1.1 | Levantar Nechí Urbano Zona 1 | 6d | 2014-04-26 | 2014-05-03 | 219, 190, 140 | 23d | 0d | Técnicos de campo [200%]; Conductor | 144h | 12,743,764.17 | 6 días | vie 04/04/14 | sáb 29/03/14 |
| 223 | 5.7.8.1.2 | Levantar Nechí Urbano Zona 2 | 6d | 2014-05-05 | 2014-05-10 | 222 | 23d | 0d | Técnicos de campo [200%]; Conductor | 144h | 12,743,764.17 | 6 días | vie 11/04/14 | sáb 05/04/14 |
| 224 | 5.7.8.2 | Levantar Nechí Rural | 4d | 2014-05-12 | 2014-05-15 | 223 | 23d | 0d | Técnicos de campo [200%]; Conductor | 96h | 8,495,842.78 | 4 días | mié 16/04/14 | sáb 12/04/14 |
| 225 | 5.7.9 | **San Jacinto Del Cauca (Bolívar)** | 12d | 2014-04-26 | 2014-05-10 |  | 28d |  |  | 288h | 25,487,528.34 | 12 días | vie 11/04/14 | sáb 29/03/14 |
| 226 | 5.7.9.1 | Levantar San Jacinto Urbano | 10d | 2014-04-26 | 2014-05-08 | 140, 219, 191 | 28d | 0d | Técnicos de campo [200%]; Conductor | 240h | 21,239,606.95 | 10 días | mié 09/04/14 | sáb 29/03/14 |
| 227 | 5.7.9.2 | Levantar San Jacinto Rural | 2d | 2014-05-09 | 2014-05-10 | 226 | 28d | 0d | Técnicos de campo [200%]; Conductor | 48h | 4,247,921.39 | 2 días | vie 11/04/14 | jue 10/04/14 |
| 228 | 5.7.10 | **Guaranda (Sucre)** | 11d | 2014-04-11 | 2014-04-25 |  | 24d |  |  | 240h | 21,239,606.95 | 11 días | vie 28/03/14 | sáb 15/03/14 |
| 229 | 5.7.10.1 | Levantar Guaranda Urbano | 8d | 2014-04-11 | 2014-04-22 | 141, 192, 198 | 24d | 0d | Técnicos de campo [200%]; Conductor | 192h | 16,991,685.56 | 8 días | mar 25/03/14 | sáb 15/03/14 |
| 230 | 5.7.10.2 | Levantar Guaranda Rural | 3d | 2014-04-23 | 2014-04-25 | 229 | 24d | 0d | Técnicos de campo [200%]; Conductor | 48h | 4,247,921.39 | 3 días | vie 28/03/14 | mié 26/03/14 |
| 231 | 5.7.11 | **Majagual (Sucre)** | 17d | 2014-04-26 | 2014-05-16 |  | 24d |  |  | 408h | 36,107,331.82 | 17 días | sáb 19/04/14 | sáb 29/03/14 |
| 232 | 5.7.11.1 | **Urbano** | 12d | 2014-04-26 | 2014-05-10 |  | 24d |  |  | 288h | 25,487,528.34 | 12 días | vie 11/04/14 | sáb 29/03/14 |
| 233 | 5.7.11.1.1 | Levantar Majagual Urbano Zona 1 | 8d | 2014-04-26 | 2014-05-06 | 230, 141, 194 | 24d | 0d | Técnicos de campo [200%]; Conductor | 192h | 16,991,685.56 | 8 días | lun 07/04/14 | sáb 29/03/14 |
| 234 | 5.7.11.1.2 | Levantar Majagual Urbano Zona 2 | 4d | 2014-05-07 | 2014-05-10 | 233 | 24d | 0d | Técnicos de campo [200%]; Conductor | 96h | 8,495,842.78 | 4 días | vie 11/04/14 | mar 08/04/14 |
| 235 | 5.7.11.2 | Levantar Majagual Rural | 5d | 2014-05-12 | 2014-05-16 | 234 | 24d | 0d | Técnicos de campo [200%]; Conductor | 120h | 10,619,803.48 | 5 días | sáb 19/04/14 | sáb 12/04/14 |

| ID | WBS | Task | Type | Duration | Start | Finish | Predecessors | Total slack | Free slack | Resources | Work | Cost | Text27 | Text29 | Text30 |
| --- | --- | --- | --- | --- | --- | --- | --- | --- | --- | --- | --- | --- | --- | --- | --- |
| 236 | 5.7.12 | **Achí (Bolívar)** |  | 16d | 2014-04-26 | 2014-05-15 |  | 25d |  |  | 384h | 33,983,371.13 | 16 días | mié 16/04/14 | sáb 29/03/14 |
| 237 | 5.7.12.1 | **Urbano** |  | 16d | 2014-04-26 | 2014-05-15 |  | 25d |  |  | 384h | 33,983,371.13 | 16 días | mié 16/04/14 | sáb 29/03/14 |
| 238 | 5.7.12.1.1 | Levantar Achí Urbano Zona 1 |  | 6d | 2014-04-26 | 2014-05-03 | 141, 230, 193 | 25d | 0d | Técnicos de campo [200%]; Conductor | 144h | 12,743,764.17 | 6 días | vie 04/04/14 | sáb 29/03/14 |
| 239 | 5.7.12.1.2 | Levantar Achí Urbano Zona 2 |  | 5d | 2014-05-05 | 2014-05-09 | 238 | 25d | 0d | Técnicos de campo [200%]; Conductor | 120h | 10,619,803.48 | 5 días | jue 10/04/14 | sáb 05/04/14 |
| 240 | 5.7.12.1.3 | Levantar Achí Rural |  | 5d | 2014-05-10 | 2014-05-15 | 239 | 25d | 0d | Técnicos de campo [200%]; Conductor | 120h | 10,619,803.48 | 5 días | mié 16/04/14 | vie 11/04/14 |
| 241 | 5.7.13 | **Sucre (Sucre)** |  | 12d | 2014-04-26 | 2014-05-10 |  | 30d |  |  | 288h | 25,487,528.34 | 12 días | vie 11/04/14 | sáb 29/03/14 |
| 242 | 5.7.13.1 | Levantar Sucre Urbano |  | 8d | 2014-04-26 | 2014-05-06 | 141, 230, 195 | 30d | 0d | Técnicos de campo [200%]; Conductor | 192h | 16,991,685.56 | 8 días | lun 07/04/14 | sáb 29/03/14 |
| 243 | 5.7.13.2 | Levantar Sucre Rural |  | 4d | 2014-05-07 | 2014-05-10 | 242 | 30d | 0d | Técnicos de campo [200%]; Conductor | 96h | 8,495,842.78 | 4 días | vie 11/04/14 | mar 08/04/14 |
| 244 | 5.7.14 | Fichas prediales totales levantadas | milestone | 0d | 2014-05-19 | 2014-05-19 | 243, 230, 227, 224, 219, 216, 213, 210, 205, 235, 240 | 42d |  |  |  |  | 0 días | vie 11/04/14 | vie 11/04/14 |
| 245 | 5.8 | **Cargue de información de encuestas prediales** |  | 21d | 2014-04-26 | 2014-05-21 |  | 25d |  |  | 291.2h | 55,222,978.08 | 21 días | jue 24/04/14 | sáb 29/03/14 |
| 246 | 5.8.1 | Cargar encuestas prediales de Magangué (Bolívar) |  | 3d | 2014-05-14 | 2014-05-16 | 205 | 26d | 0d | Digitadores [40%]; Coordinador de Información [10%]; Analistas de Información [10%]; Profesional de apoyo sistemas [20%] | 33.6h | 6,371,882.09 | 3 días | sáb 19/04/14 | mar 15/04/14 |
| 247 | 5.8.2 | Cargar encuestas prediales de San Marcos (Sucre) |  | 4d | 2014-05-05 | 2014-05-08 | 210 | 31d | 0d | Digitadores [40%]; Coordinador de Información [10%]; Analistas de Información [10%]; Profesional de apoyo sistemas [20%] | 44.8h | 8,495,842.78 | 4 días | mié 09/04/14 | sáb 05/04/14 |
| 248 | 5.8.3 | Cargar encuestas prediales de Caimito (Sucre) |  | 2d | 2014-05-16 | 2014-05-17 | 213FS-1d | 24d | 0d | Digitadores [40%]; Coordinador de Información [10%]; Analistas de Información [10%]; Profesional de apoyo sistemas [20%] | 22.4h | 4,247,921.39 | 2 días | lun 21/04/14 | sáb 19/04/14 |
| 249 | 5.8.4 | Cargar encuestas prediales de San Benito Abad (Sucre) |  | 2d | 2014-05-20 | 2014-05-21 | 216 | 21d | 0d | Digitadores [40%]; Coordinador de Información [10%]; Analistas de Información [10%]; Profesional de apoyo sistemas [20%] | 22.4h | 4,247,921.39 | 2 días | jue 24/04/14 | mié 23/04/14 |
| 250 | 5.8.5 | Cargar encuestas prediales de Ayapel (Córdoba) |  | 2d | 2014-04-26 | 2014-04-28 | 219 | 39d | 0d | Digitadores [40%]; Coordinador de Información [10%]; Analistas de Información [10%]; Profesional de apoyo sistemas [20%] | 22.4h | 4,247,921.39 | 2 días | lun 31/03/14 | sáb 29/03/14 |
| 251 | 5.8.6 | Cargar encuestas prediales de Nechi (Antioquia) |  | 2d | 2014-05-16 | 2014-05-17 | 224 | 23d | 0d | Digitadores [40%]; Coordinador de Información [10%]; Analistas de Información [10%]; Profesional de apoyo sistemas [20%] | 22.4h | 4,247,921.39 | 2 días | lun 21/04/14 | sáb 19/04/14 |
| 252 | 5.8.7 | Cargar encuestas prediales de San Jacinto del Cauca (Bolívar) |  | 2d | 2014-05-12 | 2014-05-13 | 227 | 28d | 5d | Digitadores [40%]; Coordinador de Información [10%]; Analistas de Información [10%]; Profesional de apoyo sistemas [20%] | 22.4h | 4,247,921.39 | 2 días | lun 14/04/14 | sáb 12/04/14 |
| 253 | 5.8.8 | Cargar encuestas prediales de Guaranda (Sucre) |  | 2d | 2014-04-26 | 2014-04-28 | 230 | 40d | 0d | Digitadores [40%]; Coordinador de Información [10%]; Analistas de Información [10%]; Profesional de apoyo sistemas [20%] | 22.4h | 4,247,921.39 | 2 días | lun 31/03/14 | sáb 29/03/14 |
| 254 | 5.8.9 | Cargar encuestas prediales de Majagual (Sucre) |  | 2d | 2014-05-16 | 2014-05-17 | 235FS-1d | 24d | 0d | Digitadores [40%]; Coordinador de Información [10%]; Analistas de Información [10%]; Profesional de apoyo sistemas [20%] | 22.4h | 4,247,921.39 | 2 días | lun 21/04/14 | sáb 19/04/14 |
| 255 | 5.8.10 | Cargar encuestas prediales de Achí (Bolívar) |  | 2d | 2014-05-16 | 2014-05-17 | 240 | 25d | 0d | Digitadores [40%]; Coordinador de Información [10%]; Analistas de Información [10%]; Profesional de apoyo sistemas [20%] | 22.4h | 4,247,921.39 | 2 días | lun 21/04/14 | sáb 19/04/14 |
| 256 | 5.8.11 | Cargar encuestas prediales de Sucre (Sucre) |  | 2d | 2014-05-12 | 2014-05-13 | 243 | 30d | 7d | Digitadores [40%]; Coordinador de Información [10%]; Analistas de Información [10%]; Profesional de apoyo sistemas [20%] | 33.6h | 6,371,882.09 | 2 días | lun 14/04/14 | sáb 12/04/14 |
| 257 | 5.8.12 | Encuestas prediales totales cargadas | milestone | 0d | 2014-05-21 | 2014-05-21 | 256, 255, 254, 253, 252, 251, 250, 249, 248, 247, 246 | 25d | 4d |  |  |  | 0 días | jue 24/04/14 | jue 24/04/14 |
| 258 | 5.9 | **Diagnostico técnico jurídico** |  | 75d | 2014-03-06 | 2014-06-06 |  | 21d |  |  | 528.4h | 78,586,545.74 | 63 días | sáb 10/05/14 | sáb 22/02/14 |
| 259 | 5.9.1 | **Análisis del cruce inicial de los predios de la zona de estudio** |  | 10d | 2014-03-06 | 2014-03-17 |  | 71d |  |  | 97.2h | 23,363,567.65 | 10 días | mié 05/03/14 | sáb 22/02/14 |
| 260 | 5.9.1.1 | Generación de reportes y diagramas de resultado de cruce (Análisis técnico) |  | 4d | 2014-03-06 | 2014-03-10 | 105FS-1d | 71d | 0d | Ingeniero Seguimiento de Proyecto [40%]; Gerente de Operaciones [20%] | 38.4h | 8,495,842.78 | 4 días | mié 26/02/14 | sáb 22/02/14 |
| 261 | 5.9.1.2 | Analizar el tema jurídico de los reportes y diagramas |  | 7d | 2014-03-10 | 2014-03-17 | 260FS-1d | 71d | 0d | Director de proyecto [5%]; Experto Jurídico [50%]; Experto Catastral [50%] | 58.8h | 14,867,724.87 | 7 días | mié 05/03/14 | mié 26/02/14 |
| 262 | 5.9.1.3 | Diagnóstico técnico jurídico inicial generado | milestone | 0d | 2014-03-17 | 2014-03-17 | 261 | 71d | 0d |  |  |  | 0 días | mié 05/03/14 | mié 05/03/14 |

| ID | WBS | Task | Type | Duration | Start | Finish | Predecessors | Total slack | Free slack | Constraint | Resources | Work | Cost | Text27 | Text29 | Text30 |
| --- | --- | --- | --- | --- | --- | --- | --- | --- | --- | --- | --- | --- | --- | --- | --- | --- |
| 263 | 5.9.2 | **Análisis técnico jurídico de los predios** |  | 32d | 2014-04-29 | 2014-06-06 |  | 21d |  |  |  | 431.2h | 55,222,978.09 | 32 días | sáb 10/05/14 | mar 01/04/14 |
| 264 | 5.9.2.1 | Analizar Magangué (Bolívar) |  | 2d | 2014-05-16 | 2014-05-17 | 262, 246FS-1d | 26d | 5d |  | Experto Jurídico [20%]; Experto Social [20%]; Director de proyecto [5%]; Analistas de Información [10%] | 51.6h | 6,371,882.09 | 2 días | lun 21/04/14 | sáb 19/04/14 |
| 265 | 5.9.2.2 | Analizar San Marcos (Sucre) |  | 3d | 2014-05-09 | 2014-05-12 | 262, 247 | 31d | 10d |  | Experto Jurídico [20%]; Experto Social [20%]; Director de proyecto [5%]; Analistas de Información [10%] | 51.6h | 6,371,882.09 | 3 días | sáb 12/04/14 | jue 10/04/14 |
| 266 | 5.9.2.3 | Analizar Caimito (Sucre) |  | 2d | 2014-05-19 | 2014-05-20 | 248, 262 | 24d | 3d |  | Experto Jurídico [50%]; Experto Social [50%]; Director de proyecto [5%]; Analistas de Información [10%] | 18.4h | 4,247,921.39 | 2 días | mié 23/04/14 | mar 22/04/14 |
| 267 | 5.9.2.4 | Analizar San Benito Abad (Sucre) |  | 2d | 2014-05-22 | 2014-05-23 | 249, 262 | 21d | 0d |  | Experto Jurídico [50%]; Experto Social [50%]; Director de proyecto [5%]; Analistas de Información [10%] | 18.4h | 4,247,921.39 | 2 días | sáb 26/04/14 | vie 25/04/14 |
| 268 | 5.9.2.5 | Analizar Ayapel (Córdoba) |  | 3d | 2014-04-29 | 2014-05-02 | 262FS-1d, 250 | 39d | 18d |  | Experto Jurídico [50%]; Experto Social [50%]; Director de proyecto [5%]; Analistas de Información [10%] | 27.6h | 6,371,882.09 | 3 días | jue 03/04/14 | mar 01/04/14 |
| 269 | 5.9.2.6 | Analizar Nechi (Antioquia) |  | 2d | 2014-05-17 | 2014-05-19 | 251FS-1d, 262 | 23d | 0d |  | Experto Jurídico [50%]; Experto Social [50%]; Director de proyecto [5%]; Analistas de Información [10%] | 18.4h | 4,247,921.39 | 2 días | mar 22/04/14 | lun 21/04/14 |
| 270 | 5.9.2.7 | Analizar San Jacinto del Cauca (Bolívar) |  | 2d | 2014-05-20 | 2014-05-21 | 269, 252, 262 | 23d | 2d |  | Experto Jurídico [50%]; Experto Social [50%]; Director de proyecto [5%]; Analistas de Información [10%] | 18.4h | 4,247,921.39 | 2 días | jue 24/04/14 | mié 23/04/14 |
| 271 | 5.9.2.8 | Analizar Guaranda (Sucre) |  | 2d | 2014-04-29 | 2014-04-30 | 262FS-1d, 253 | 40d | 19d |  | Experto Jurídico [50%]; Experto Social [50%]; Director de proyecto [5%]; Analistas de Información [10%] | 27.6h | 6,371,882.09 | 2 días | mié 02/04/14 | mar 01/04/14 |
| 272 | 5.9.2.9 | Analizar Majagual (Sucre) |  | 2d | 2014-05-19 | 2014-05-20 | 262, 254 | 24d | 3d |  | Experto Jurídico [20%]; Experto Social [20%]; Director de proyecto [5%]; Analistas de Información [10%] | 34.4h | 4,247,921.39 | 2 días | mié 23/04/14 | mar 22/04/14 |
| 273 | 5.9.2.10 | Analizar Achí (Bolívar) |  | 2d | 2014-05-17 | 2014-05-19 | 262, 255FS-1d | 25d | 4d |  | Experto Jurídico [50%]; Experto Social [50%]; Director de proyecto [5%]; Analistas de Información [10%] | 18.4h | 4,247,921.39 | 2 días | mar 22/04/14 | lun 21/04/14 |
| 274 | 5.9.2.11 | Analizar Sucre (Sucre) |  | 2d | 2014-05-24 | 2014-05-26 | 262, 256, 264, 265, 266, 267, 268, 269, 270, 271, 272, 273 | 21d | 0d |  | Experto Jurídico [20%]; Experto Social [20%]; Director de proyecto [5%]; Analistas de Información [10%] | 34.4h | 4,247,921.39 | 2 días | mar 29/04/14 | lun 28/04/14 |
| 275 | 5.9.2.12 | Generar informe de fichas cargadas |  | 14d | 2014-05-21 | 2014-06-06 | 274FS-5d, 257FS-5d | 21d | 0d |  | Experto SIG | 112h |  | 14 días | sáb 10/05/14 | jue 24/04/14 |
| 276 | 5.10 | Base de datos (Entregable 4) cargada | milestone | 0d | 2014-06-06 | 2014-06-06 | 275 | 21d | 0d |  |  |  |  | 0 días | sáb 10/05/14 | sáb 10/05/14 |
| 277 | 6 | **Fase de actualización de valores de zonas geoeconómicas** |  | 72d | 2014-03-14 | 2014-06-11 |  | 3d |  |  |  | 6564h | 987,641,723.38 | 100 días | vie 13/06/14 | mié 12/02/14 |
| 278 | 6.1 | **Preparación de estudio de mercado** |  | 16d | 2014-03-14 | 2014-04-02 |  | 3d |  |  |  | 852h | 112,569,916.88 | 44 días | vie 04/04/14 | mié 12/02/14 |
| 279 | 6.1.1 | Entrega de zonas físicas |  | 1d | 2014-03-14 | 2014-03-14 |  | 83d | 0d | finish no earlier than 2014-03-14 |  |  |  |  |  |  |
| 280 | 6.1.2 | Entrega de informes de gerencia sectorial |  | 1d | 2014-03-14 | 2014-03-14 |  | 3d | 0d | finish no earlier than 2014-03-14 |  |  |  |  |  |  |
| 281 | 6.1.3 | **Verificación espacial de zonas físicas** |  | 10d | 2014-03-17 | 2014-03-28 |  | 83d |  |  |  | 280h | 36,107,331.83 | 22 días | sáb 08/03/14 | mié 12/02/14 |
| 282 | 6.1.3.1 | Verificar Magangué / Achi |  | 6d | 2014-03-17 | 2014-03-22 | 279FS+1d | 87d |  |  | Perito Avaluador; Analistas SIG | 80h | 10,619,803.48 | 6 días | mar 18/02/14 | mié 12/02/14 |
| 283 | 6.1.3.2 | Verificar San Marcos / Guaranda |  | 4d | 2014-03-17 | 2014-03-20 | 279FS+1d, 38, 112 | 89d |  |  | Perito Avaluador; Analistas SIG | 64h | 8,495,842.78 | 4 días | sáb 22/02/14 | mié 19/02/14 |
| 284 | 6.1.3.3 | Verificar Majagual / Nechí / Caimito |  | 4d | 2014-03-17 | 2014-03-20 | 279FS+1d, 38, 112 | 89d |  |  | Perito Avaluador; Analistas SIG | 64h | 8,495,842.78 | 4 días | jue 27/02/14 | lun 24/02/14 |
| 285 | 6.1.3.4 | Verificar Ayapel / San Benito Abad / San Jacinto del Cauca / Sucre |  | 6d | 2014-03-17 | 2014-03-22 | 279FS+1d, 38, 112 | 83d | 0d |  | Perito Avaluador; Analistas SIG | 48h | 6,371,882.09 | 4 días | mar 04/03/14 | vie 28/02/14 |
| 286 | 6.1.3.5 | Cruzar zonas físicas actualizadas con zonas económicas del IGAC |  | 4d | 2014-03-25 | 2014-03-28 | 285 | 83d | 0d |  | Experto Social; Perito Avaluador; Analistas SIG | 24h | 2,123,960.7 | 4 días | sáb 08/03/14 | mié 05/03/14 |
| 287 | 6.1.3.6 | Mapa actualizado de zonas físicas generado | milestone | 0d | 2014-03-28 | 2014-03-28 | 286 | 83d | 0d |  |  |  |  | 0 días | sáb 08/03/14 | sáb 08/03/14 |

Notes:
- 276: Entregable 4 / La base de datos organizada con los documentos que contenga~las fichas prediales de todos los predios objeto del estudio de la región, con todas las variables catastrales y de la propiedad. ~

| ID | WBS | Task | Type | Duration | Start | Finish | Predecessors | Total slack | Free slack | Resources | Work | Cost | Text27 | Text29 | Text30 |
| --- | --- | --- | --- | --- | --- | --- | --- | --- | --- | --- | --- | --- | --- | --- | --- |
| 288 | 6.1.4 | **Análisis de caracterización de predios urbanos** |  | 6d | 2014-03-17 | 2014-03-22 |  | 3d |  |  | 224h | 44,603,174.61 | 15 días | vie 21/03/14 | mié 05/03/14 |
| 289 | 6.1.4.1 | Analizar caracterización de Magangué |  | 3d | 2014-03-17 | 2014-03-19 | 280FS+1d, 287 | 90d |  | Perito Avaluador | 24h | 6,371,882.09 | 3 días | vie 07/03/14 | mié 05/03/14 |
| 290 | 6.1.4.2 | Analizar caracterización de San Marcos / Caimito |  | 3d | 2014-03-17 | 2014-03-19 | 280FS+1d, 287 | 90d |  | Perito Avaluador | 32h | 8,495,842.78 | 3 días | mar 11/03/14 | sáb 08/03/14 |
| 291 | 6.1.4.3 | Analizar caracterización de Majagual / Nechí / Caimito |  | 3d | 2014-03-17 | 2014-03-19 | 280FS+1d, 287 | 3d | 0d | Perito Avaluador | 24h | 6,371,882.09 | 3 días | vie 14/03/14 | mié 12/03/14 |
| 292 | 6.1.4.4 | Analizar caracterización de Ayapel / San Benito Abad / San Jacinto del Cauca / Sucre |  | 3d | 2014-03-20 | 2014-03-22 | 291 | 3d | 0d | Perito Avaluador | 32h | 8,495,842.78 | 3 días | mar 18/03/14 | sáb 15/03/14 |
| 293 | 6.1.4.5 | Generar informe de análisis de caracterización |  | 3d | 2014-03-20 | 2014-03-22 | 292SS | 3d | 0d | Perito Avaluador; Auxiliar Administrativo | 112h | 14,867,724.87 | 6 días | vie 21/03/14 | sáb 15/03/14 |
| 294 | 6.1.4.6 | Informe de Análisis de caracterización realizado | milestone | 0d | 2014-03-22 | 2014-03-22 | 293 | 3d | 0d |  |  |  | 0 días | vie 21/03/14 | vie 21/03/14 |
| 295 | 6.1.5 | **Definición de muestra de puntos** |  | 3d | 2014-03-25 | 2014-03-27 |  | 3d |  |  | 73.6h | 4,247,921.39 | 3 días | mié 26/03/14 | sáb 22/03/14 |
| 296 | 6.1.5.1 | Definir puntos para investigación de mercado |  | 3d | 2014-03-25 | 2014-03-27 | 294 | 3d | 0d | Perito Avaluador [200%]; Analistas SIG [200%]; Profesional de apoyo sistemas [20%]; Coordinador de Información [20%]; Experto Social [20%] | 73.6h | 4,247,921.39 | 3 días | mié 26/03/14 | sáb 22/03/14 |
| 297 | 6.1.5.2 | Predios para investigación de mercado definidos | milestone | 0d | 2014-03-27 | 2014-03-27 | 296 | 3d | 0d |  |  |  | 0 días | mié 26/03/14 | mié 26/03/14 |
| 298 | 6.1.6 | **Soporte a la investigación de mercado** |  | 5d | 2014-03-28 | 2014-04-02 |  | 3d |  |  | 274.4h | 27,611,489.05 | 8 días | vie 04/04/14 | jue 27/03/14 |
| 299 | 6.1.6.1 | Generar Plan de trabajo de campo (rutas y desplazamientos) |  | 3d | 2014-03-28 | 2014-03-31 | 297 | 3d | 0d | Perito Avaluador [50%]; Director de proyecto [10%]; Gerente de Operaciones [10%]; Analistas SIG [40%]; Experto Catastral [30%] | 45.6h | 6,371,882.09 | 3 días | sáb 29/03/14 | jue 27/03/14 |
| 300 | 6.1.6.2 | Definir formato para captura de investigación de mercado |  | 3d | 2014-03-28 | 2014-03-31 | 297 | 3d | 0d | Perito Avaluador [200%]; Director de proyecto [5%]; Gerente de Operaciones [10%]; Analistas de Información [50%] | 84.8h | 8,495,842.78 | 3 días | sáb 29/03/14 | jue 27/03/14 |
| 301 | 6.1.6.3 | Generar mapas de soporte a desplazamientos |  | 2d | 2014-04-01 | 2014-04-02 | 299 | 3d | 0d | Analistas SIG [200%] | 48h | 6,371,882.09 | 3 días | mié 02/04/14 | lun 31/03/14 |
| 302 | 6.1.6.4 | Estandarizar metodologías a peritos avaluadores (Inducción y capacitación) |  | 2d | 2014-04-01 | 2014-04-02 | 300, 299 | 3d | 0d | Perito Avaluador [400%] | 96h | 6,371,882.09 | 2 días | vie 04/04/14 | jue 03/04/14 |
| 303 | 6.2 | **Realización de estudio de mercado** |  | 46d | 2014-04-03 | 2014-05-29 |  | 3d |  |  | 2768h | 367,445,200.27 | 46 días | sáb 31/05/14 | sáb 05/04/14 |
| 304 | 6.2.1 | **Estudio de Magangué (Bolívar)** |  | 46d | 2014-04-03 | 2014-05-29 |  | 3d | 0d |  | 736h | 97,702,191.98 | 46 días | sáb 31/05/14 | sáb 05/04/14 |
| 305 | 6.2.1.1 | **Estudio Urbano** |  | 33d | 2014-04-03 | 2014-05-14 |  | 3d |  |  | 528h | 70,090,702.94 | 33 días | vie 16/05/14 | sáb 05/04/14 |
| 306 | 6.2.1.1.1 | Estudiar Mercado Urbano Magangué Zona 1 |  | 10d | 2014-04-03 | 2014-04-14 | 302, 301 | 3d | 0d | Perito Avaluador; Conductor | 160h | 21,239,606.95 | 10 días | mié 16/04/14 | sáb 05/04/14 |
| 307 | 6.2.1.1.2 | Estudiar Mercado Urbano Magangué Zona 2 |  | 11d | 2014-04-15 | 2014-04-29 | 306 | 3d | 0d | Perito Avaluador; Conductor | 176h | 23,363,567.65 | 11 días | vie 02/05/14 | sáb 19/04/14 |
| 308 | 6.2.1.1.3 | Estudiar Mercado Urbano Magangué Zona 3 |  | 12d | 2014-04-30 | 2014-05-14 | 307 | 3d | 0d | Perito Avaluador; Conductor | 192h | 25,487,528.34 | 12 días | vie 16/05/14 | sáb 03/05/14 |
| 309 | 6.2.1.2 | **Rural** |  | 13d | 2014-05-15 | 2014-05-29 |  | 3d |  |  | 208h | 27,611,489.04 | 13 días | sáb 31/05/14 | sáb 17/05/14 |
| 310 | 6.2.1.2.1 | Estudiar Mercado Rural Magangué Zona 1 |  | 7d | 2014-05-15 | 2014-05-22 | 308 | 3d | 0d | Perito Avaluador; Conductor | 112h | 14,867,724.87 | 7 días | sáb 24/05/14 | sáb 17/05/14 |
| 311 | 6.2.1.2.2 | Estudiar Mercado Rural Magangué Zona 2 |  | 6d | 2014-05-23 | 2014-05-29 | 310 | 3d | 0d | Perito Avaluador; Conductor | 96h | 12,743,764.17 | 6 días | sáb 31/05/14 | lun 26/05/14 |

| ID | WBS | Task | Type | Duration | Start | Finish | Predecessors | Total slack | Free slack | Resources | Work | Cost | Text27 | Text29 | Text30 |
| --- | --- | --- | --- | --- | --- | --- | --- | --- | --- | --- | --- | --- | --- | --- | --- |
| 312 | 6.2.2 | **San Marcos (Sucre)** |  | 21d | 2014-04-03 | 2014-04-29 |  | 12d |  |  | 336h | 44,603,174.6 | 21 días | vie 02/05/14 | sáb 05/04/14 |
| 313 | 6.2.2.1 | Estudiar Mercado Urbano San Marcos |  | 10d | 2014-04-03 | 2014-04-14 | 302, 301 | 12d | 0d | Perito Avaluador; Conductor | 160h | 21,239,606.95 | 10 días | mié 16/04/14 | sáb 05/04/14 |
| 314 | 6.2.2.2 | Estudiar Mercado Rural San Marcos |  | 11d | 2014-04-15 | 2014-04-29 | 313 | 12d | 0d | Perito Avaluador; Conductor | 176h | 23,363,567.65 | 11 días | vie 02/05/14 | sáb 19/04/14 |
| 315 | 6.2.3 | Estudiar Mercado Caimito (Sucre) |  | 8d | 2014-04-30 | 2014-05-09 | 314 | 12d | 0d | Perito Avaluador; Conductor | 128h | 16,991,685.56 | 8 días | lun 12/05/14 | sáb 03/05/14 |
| 316 | 6.2.4 | Estudiar Mercado San Benito Abad (Sucre) |  | 8d | 2014-05-10 | 2014-05-19 | 315 | 12d | 0d | Perito Avaluador; Conductor | 128h | 16,991,685.56 | 8 días | mié 21/05/14 | mar 13/05/14 |
| 317 | 6.2.5 | **Ayapel (Córdoba)** |  | 17d | 2014-04-03 | 2014-04-24 |  | 4d |  |  | 272h | 36,107,331.82 | 17 días | sáb 26/04/14 | sáb 05/04/14 |
| 318 | 6.2.5.1 | Estudiar Mercado Urbano Ayapel |  | 10d | 2014-04-03 | 2014-04-14 | 302, 301 | 4d | 0d | Perito Avaluador; Conductor | 160h | 21,239,606.95 | 10 días | mié 16/04/14 | sáb 05/04/14 |
| 319 | 6.2.5.2 | Estudiar Mercado Rural Ayapel |  | 7d | 2014-04-15 | 2014-04-24 | 318 | 4d | 0d | Perito Avaluador; Conductor | 112h | 14,867,724.87 | 7 días | sáb 26/04/14 | sáb 19/04/14 |
| 320 | 6.2.6 | **Nechi (Antioquia)** |  | 13d | 2014-04-25 | 2014-05-10 |  | 4d |  |  | 208h | 27,611,489.04 | 13 días | mar 13/05/14 | lun 28/04/14 |
| 321 | 6.2.6.1 | Estudiar Mercado Urbano Nechí |  | 5d | 2014-04-25 | 2014-04-30 | 319 | 4d | 0d | Perito Avaluador; Conductor | 80h | 10,619,803.48 | 5 días | sáb 03/05/14 | lun 28/04/14 |
| 322 | 6.2.6.2 | Estudiar Mercado Rural Nechí |  | 8d | 2014-05-02 | 2014-05-10 | 321 | 4d | 0d | Perito Avaluador; Conductor | 128h | 16,991,685.56 | 8 días | mar 13/05/14 | lun 05/05/14 |
| 323 | 6.2.7 | **San Jacinto del Cauca (Bolívar)** |  | 15d | 2014-05-12 | 2014-05-28 |  | 4d | 1d |  | 240h | 31,859,410.43 | 15 días | vie 30/05/14 | mié 14/05/14 |
| 324 | 6.2.7.1 | Estudiar Mercado Urbano San Jacinto |  | 5d | 2014-05-12 | 2014-05-16 | 322 | 4d | 0d | Perito Avaluador; Conductor | 80h | 10,619,803.48 | 5 días | lun 19/05/14 | mié 14/05/14 |
| 325 | 6.2.7.2 | Estudiar Mercado Rural San Jacinto |  | 10d | 2014-05-17 | 2014-05-28 | 324 | 4d | 0d | Perito Avaluador; Conductor | 160h | 21,239,606.95 | 10 días | vie 30/05/14 | mar 20/05/14 |
| 326 | 6.2.8 | Estudiar Mercado Guaranda (Sucre) |  | 10d | 2014-04-03 | 2014-04-14 | 302, 301 | 4d | 0d | Perito Avaluador; Conductor | 160h | 21,239,606.95 | 10 días | mié 16/04/14 | sáb 05/04/14 |
| 327 | 6.2.9 | Estudiar Mercado Majagual (Sucre) |  | 11d | 2014-04-15 | 2014-04-29 | 326 | 4d | 0d | Perito Avaluador; Conductor | 176h | 23,363,567.65 | 11 días | vie 02/05/14 | sáb 19/04/14 |
| 328 | 6.2.10 | Estudiar Mercado Achí (Bolívar) |  | 12d | 2014-04-30 | 2014-05-14 | 327 | 4d | 0d | Perito Avaluador; Conductor | 192h | 25,487,528.34 | 12 días | vie 16/05/14 | sáb 03/05/14 |
| 329 | 6.2.11 | Estudiar Mercado Sucre (Sucre) |  | 12d | 2014-05-15 | 2014-05-28 | 328 | 4d | 0d | Perito Avaluador; Conductor | 192h | 25,487,528.34 | 12 días | vie 30/05/14 | sáb 17/05/14 |
| 330 | 6.2.12 | Estudio de mercado realizado | milestone | 0d | 2014-05-29 | 2014-05-29 | 316, 329, 304, 323 | 3d | 0d |  |  |  | 0 días | sáb 31/05/14 | sáb 31/05/14 |
| 331 | 6.3 | **Procesamiento y cargue de encuestas de mercado** |  | 45d | 2014-04-07 | 2014-05-31 |  | 31d |  |  | 1904h | 361,073,318.18 | 45 días | mié 04/06/14 | mié 09/04/14 |
| 332 | 6.3.1 | **Procesamiento de Magangué (Bolívar)** |  | 45d | 2014-04-07 | 2014-05-31 |  | 31d |  |  | 515.2h | 97,702,191.98 | 45 días | mié 04/06/14 | mié 09/04/14 |
| 333 | 6.3.1.1 | **Procesamiento Urbano** |  | 31d | 2014-04-07 | 2014-05-15 |  | 45d |  |  | 369.6h | 70,090,702.94 | 31 días | sáb 17/05/14 | mié 09/04/14 |
| 334 | 6.3.1.1.1 | Procesar Zona 1 |  | 10d | 2014-04-07 | 2014-04-19 | 306SS+3d | 66d |  | Digitadores [40%]; Coordinador de Información [10%]; Analistas de Información [10%]; Profesional de apoyo sistemas [20%] | 112h | 21,239,606.95 | 10 días | mar 22/04/14 | mié 09/04/14 |
| 335 | 6.3.1.1.2 | Procesar Zona 2 |  | 10d | 2014-04-21 | 2014-05-02 | 307SS+3d | 56d |  | Digitadores [40%]; Coordinador de Información [10%]; Analistas de Información [10%]; Profesional de apoyo sistemas [20%] | 123.2h | 23,363,567.65 | 10 días | lun 05/05/14 | mié 23/04/14 |
| 336 | 6.3.1.1.3 | Procesar Zona 3 |  | 10d | 2014-05-05 | 2014-05-15 | 308SS+3d | 45d |  | Digitadores [40%]; Coordinador de Información [10%]; Analistas de Información [10%]; Profesional de apoyo sistemas [20%] | 134.4h | 25,487,528.34 | 10 días | sáb 17/05/14 | mié 07/05/14 |

| ID | WBS | Task | Type | Duration | Start | Finish | Predecessors | Total slack | Free slack | Resources | Work | Cost | Text27 | Text29 | Text30 |
| --- | --- | --- | --- | --- | --- | --- | --- | --- | --- | --- | --- | --- | --- | --- | --- |
| 337 | 6.3.1.2 | **Procesamiento Rural** |  | 13d | 2014-05-17 | 2014-05-31 |  | 13d |  |  | 145.6h | 27,611,489.04 | 13 días | mié 04/06/14 | mar 20/05/14 |
| 338 | 6.3.1.2.1 | Procesar Zona 1 |  | 6d | 2014-05-17 | 2014-05-23 | 310SS+2d | 38d |  | Digitadores [40%]; Coordinador de Información [10%]; Analistas de Información [10%]; Profesional de apoyo sistemas [20%] | 78.4h | 14,867,724.87 | 6 días | lun 26/05/14 | mar 20/05/14 |
| 339 | 6.3.1.2.2 | Procesar Zona 2 |  | 6d | 2014-05-26 | 2014-05-31 | 311SS+2d | 6d | 0d | Digitadores [40%]; Coordinador de Información [10%]; Analistas de Información [10%]; Profesional de apoyo sistemas [20%] | 67.2h | 12,743,764.17 | 6 días | mié 04/06/14 | mié 28/05/14 |
| 340 | 6.3.2 | **Procesamiento San Marcos (Sucre)** |  | 20d | 2014-04-07 | 2014-05-02 |  | 36d | 23d |  | 224h | 42,479,213.9 | 20 días | lun 05/05/14 | mié 09/04/14 |
| 341 | 6.3.2.1 | Procesar Urbano |  | 10d | 2014-04-07 | 2014-04-19 | 313SS+3d | 46d |  | Digitadores [40%]; Coordinador de Información [10%]; Analistas de Información [10%]; Profesional de apoyo sistemas [20%] | 112h | 21,239,606.95 | 10 días | mar 22/04/14 | mié 09/04/14 |
| 342 | 6.3.2.2 | Procesar Rural |  | 10d | 2014-04-21 | 2014-05-02 | 314SS+3d | 28d | 0d | Digitadores [40%]; Coordinador de Información [10%]; Analistas de Información [10%]; Profesional de apoyo sistemas [20%] | 112h | 21,239,606.95 | 10 días | lun 05/05/14 | mié 23/04/14 |
| 343 | 6.3.3 | Procesar Caimito (Sucre) |  | 7d | 2014-05-03 | 2014-05-10 | 315SS+2d | 25d | 0d | Digitadores [40%]; Coordinador de Información [10%]; Analistas de Información [10%]; Profesional de apoyo sistemas [20%] | 89.6h | 16,991,685.56 | 7 días | mar 13/05/14 | mar 06/05/14 |
| 344 | 6.3.4 | Procesar San Benito Abad (Sucre) |  | 7d | 2014-05-13 | 2014-05-20 | 316SS+2d | 17d | 0d | Digitadores [40%]; Coordinador de Información [10%]; Analistas de Información [10%]; Profesional de apoyo sistemas [20%] | 89.6h | 16,991,685.56 | 7 días | jue 22/05/14 | jue 15/05/14 |
| 345 | 6.3.5 | **Procesamiento Ayapel (Córdoba)** |  | 15d | 2014-04-07 | 2014-04-25 |  | 41d | 28d |  | 190.4h | 36,107,331.82 | 15 días | lun 28/04/14 | mié 09/04/14 |
| 346 | 6.3.5.1 | Procesar Urbano |  | 10d | 2014-04-07 | 2014-04-19 | 318SS+3d | 46d |  | Digitadores [40%]; Coordinador de Información [10%]; Analistas de Información [10%]; Profesional de apoyo sistemas [20%] | 112h | 21,239,606.95 | 10 días | mar 22/04/14 | mié 09/04/14 |
| 347 | 6.3.5.2 | Procesar Rural |  | 6d | 2014-04-19 | 2014-04-25 | 319SS+2d | 35d | 0d | Digitadores [40%]; Coordinador de Información [10%]; Analistas de Información [10%]; Profesional de apoyo sistemas [20%] | 78.4h | 14,867,724.87 | 6 días | lun 28/04/14 | mar 22/04/14 |
| 348 | 6.3.6 | **Procesamiento Nechi (Antioquia)** |  | 12d | 2014-04-28 | 2014-05-12 |  | 28d | 15d |  | 168h | 31,859,410.43 | 12 días | mié 14/05/14 | mié 30/04/14 |
| 349 | 6.3.6.1 | Procesar Urbano |  | 5d | 2014-04-28 | 2014-05-03 | 321SS+2d | 35d |  | Digitadores [40%]; Coordinador de Información [10%]; Analistas de Información [10%]; Profesional de apoyo sistemas [20%] | 67.2h | 12,743,764.17 | 5 días | mar 06/05/14 | mié 30/04/14 |
| 350 | 6.3.6.2 | Procesar Rural |  | 7d | 2014-05-05 | 2014-05-12 | 322SS+2d | 24d | 0d | Digitadores [40%]; Coordinador de Información [10%]; Analistas de Información [10%]; Profesional de apoyo sistemas [20%] | 100.8h | 19,115,646.26 | 7 días | mié 14/05/14 | mié 07/05/14 |
| 351 | 6.3.7 | **Procesamiento San Jacinto del Cauca (Bolívar)** |  | 13d | 2014-05-14 | 2014-05-28 |  | 14d | 1d |  | 134.4h | 25,487,528.34 | 13 días | vie 30/05/14 | vie 16/05/14 |
| 352 | 6.3.7.1 | Procesar Urbano |  | 4d | 2014-05-14 | 2014-05-17 | 324SS+2d | 23d |  | Digitadores [40%]; Coordinador de Información [10%]; Analistas de Información [10%]; Profesional de apoyo sistemas [20%] | 44.8h | 8,495,842.78 | 4 días | mar 20/05/14 | vie 16/05/14 |
| 353 | 6.3.7.2 | Procesar Rural |  | 8d | 2014-05-20 | 2014-05-28 | 325SS+2d | 10d | 0d | Digitadores [40%]; Coordinador de Información [10%]; Analistas de Información [10%]; Profesional de apoyo sistemas [20%] | 89.6h | 16,991,685.56 | 8 días | vie 30/05/14 | jue 22/05/14 |
| 354 | 6.3.8 | Procesar Guaranda (Sucre) |  | 10d | 2014-04-07 | 2014-04-19 | 326SS+3d | 42d | 0d | Digitadores [40%]; Coordinador de Información [10%]; Analistas de Información [10%]; Profesional de apoyo sistemas [20%] | 112h | 21,239,606.95 | 10 días | mar 22/04/14 | mié 09/04/14 |
| 355 | 6.3.9 | Procesar Majagual (Sucre) |  | 10d | 2014-04-21 | 2014-05-02 | 327SS+3d | 30d | 0d | Digitadores [40%]; Coordinador de Información [10%]; Analistas de Información [10%]; Profesional de apoyo sistemas [20%] | 123.2h | 23,363,567.65 | 10 días | lun 05/05/14 | mié 23/04/14 |
| 356 | 6.3.10 | Procesar Achí (Bolívar) |  | 10d | 2014-05-05 | 2014-05-15 | 328SS+3d | 21d | 0d | Digitadores [40%]; Coordinador de Información [10%]; Analistas de Información [10%]; Profesional de apoyo sistemas [20%] | 134.4h | 25,487,528.34 | 10 días | sáb 17/05/14 | mié 07/05/14 |
| 357 | 6.3.11 | Procesar Sucre (Sucre) |  | 10d | 2014-05-19 | 2014-05-29 | 329SS+3d | 13d | 0d | Digitadores [40%]; Coordinador de Información [10%]; Analistas de Información [10%]; Profesional de apoyo sistemas [20%] | 123.2h | 23,363,567.65 | 10 días | sáb 31/05/14 | mié 21/05/14 |
| 358 | 6.3.12 | Información de estudio de mercado cargada | milestone | 0d | 2014-05-29 | 2014-05-29 | 340, 343, 344, 345, 348, 351, 354, 355, 356, 357 | 13d | 10d |  |  |  | 0 días | sáb 31/05/14 | sáb 31/05/14 |
| 359 | 6.4 | **Análisis estadísticos de estudios de mercado** |  | 42d | 2014-04-21 | 2014-06-10 |  | 24d |  |  | 309.6h | 53,099,017.42 | 42 días | jue 12/06/14 | mié 23/04/14 |
| 360 | 6.4.1 | Analizar Magangué (Bolívar) |  | 3d | 2014-06-03 | 2014-06-05 | 339 | 6d | 0d | Perito Avaluador [30%]; Analistas de Información [40%]; Profesional de apoyo sistemas [10%] | 72h | 12,743,764.17 | 3 días | sáb 07/06/14 | jue 05/06/14 |
| 361 | 6.4.2 | Analizar San Marcos (Sucre) |  | 3d | 2014-05-03 | 2014-05-06 | 342 | 28d | 0d | Perito Avaluador [30%]; Analistas de Información [40%]; Profesional de apoyo sistemas [10%] | 36h | 6,371,882.09 | 3 días | jue 08/05/14 | mar 06/05/14 |
| 362 | 6.4.3 | Analizar Caimito (Sucre) |  | 1d | 2014-05-12 | 2014-05-12 | 343 | 25d | 0d | Perito Avaluador [30%]; Analistas de Información [40%]; Profesional de apoyo sistemas [10%] | 12h | 2,123,960.7 | 1 día | mié 14/05/14 | mié 14/05/14 |
| 363 | 6.4.4 | Analizar San Benito Abad (Sucre) |  | 1d | 2014-05-21 | 2014-05-21 | 344 | 17d | 0d | Perito Avaluador [30%]; Analistas de Información [40%]; Profesional de apoyo sistemas [10%] | 12h | 2,123,960.7 | 1 día | vie 23/05/14 | vie 23/05/14 |
| 364 | 6.4.5 | Analizar Ayapel (Córdoba) |  | 2d | 2014-04-26 | 2014-04-28 | 347 | 35d | 0d | Perito Avaluador [30%]; Analistas de Información [40%]; Profesional de apoyo sistemas [10%] | 36h | 6,371,882.09 | 2 días | mié 30/04/14 | mar 29/04/14 |
| 365 | 6.4.6 | Analizar Nechi (Antioquia) |  | 1d | 2014-05-13 | 2014-05-13 | 350 | 24d | 0d | Perito Avaluador [30%]; Analistas de Información [40%]; Profesional de apoyo sistemas [10%] | 12h | 2,123,960.7 | 1 día | jue 15/05/14 | jue 15/05/14 |
| 366 | 6.4.7 | Analizar San Jacinto del Cauca (Bolívar) |  | 1d | 2014-05-29 | 2014-05-29 | 353 | 10d | 0d | Perito Avaluador [30%]; Analistas de Información [40%]; Profesional de apoyo sistemas [10%] | 12h | 2,123,960.7 | 1 día | sáb 31/05/14 | sáb 31/05/14 |
| 367 | 6.4.8 | Analizar Guaranda (Sucre) |  | 1d | 2014-04-21 | 2014-04-21 | 354 | 42d | 0d | Perito Avaluador [30%]; Analistas de Información [40%]; Profesional de apoyo sistemas [10%] | 12h | 2,123,960.7 | 1 día | mié 23/04/14 | mié 23/04/14 |
| 368 | 6.4.9 | Analizar Majagual (Sucre) |  | 2d | 2014-05-03 | 2014-05-05 | 355 | 30d | 0d | Perito Avaluador [30%]; Analistas de Información [40%]; Profesional de apoyo sistemas [10%] | 24h | 4,247,921.39 | 2 días | mié 07/05/14 | mar 06/05/14 |
| 369 | 6.4.10 | Analizar Achí (Bolívar) |  | 1d | 2014-05-16 | 2014-05-16 | 356 | 21d | 0d | Perito Avaluador [30%]; Analistas de Información [40%]; Profesional de apoyo sistemas [10%] | 12h | 2,123,960.7 | 1 día | lun 19/05/14 | lun 19/05/14 |
| 370 | 6.4.11 | Analizar Sucre (Sucre) |  | 1d | 2014-05-30 | 2014-05-30 | 357 | 14d | 0d | Perito Avaluador [30%]; Analistas de Información [40%]; Profesional de apoyo sistemas [10%] | 12h | 2,123,960.7 | 1 día | mar 03/06/14 | mar 03/06/14 |
| 371 | 6.4.12 | Generar informe de análisis estadístico |  | 4d | 2014-06-06 | 2014-06-10 | 370, 360, 361, 362, 363, 364, 365, 366, 367, 368, 369 | 24d | 0d | Perito Avaluador [50%]; Auxiliar Administrativo [50%]; Gerente de Operaciones [20%]; Director de proyecto [10%] | 57.6h | 8,495,842.78 | 4 días | jue 12/06/14 | lun 09/06/14 |
| 372 | 6.4.13 | Informe final de análisis estadísticos realizado | milestone | 0d | 2014-06-10 | 2014-06-10 | 371 | 24d |  |  |  |  | 0 días | jue 12/06/14 | jue 12/06/14 |

| ID | WBS | Task | Type | Duration | Start | Finish | Predecessors | Total slack | Free slack | Constraint | Resources | Work | Cost | Text27 | Text29 | Text30 |
| --- | --- | --- | --- | --- | --- | --- | --- | --- | --- | --- | --- | --- | --- | --- | --- | --- |
| 373 | 6.5 | **Ajuste y actualización de valores de zonas geoeconómicas** |  | 42d | 2014-04-22 | 2014-06-11 |  | 6d |  |  |  | 519.2h | 70,090,702.98 | 42 días | vie 13/06/14 | jue 24/04/14 |
| 374 | 6.5.1 | Actualizar Magangué (Bolívar) |  | 5d | 2014-06-06 | 2014-06-11 | 360 | 6d | 0d |  | Perito Avaluador [50%]; Analistas SIG [50%]; Experto Social [10%] | 76.8h | 12,743,764.17 | 5 días | vie 13/06/14 | lun 09/06/14 |
| 375 | 6.5.2 | Actualizar San Marcos (Sucre) |  | 3d | 2014-05-07 | 2014-05-09 | 361 | 28d | 0d |  | Perito Avaluador [50%]; Analistas SIG [50%]; Experto Social [10%] | 51.2h | 8,495,842.78 | 3 días | lun 12/05/14 | vie 09/05/14 |
| 376 | 6.5.3 | Actualizar Caimito (Sucre) |  | 1d | 2014-05-13 | 2014-05-13 | 362 | 25d | 0d |  | Perito Avaluador [50%]; Analistas SIG [50%]; Experto Social [10%] | 12.8h | 2,123,960.7 | 1 día | jue 15/05/14 | jue 15/05/14 |
| 377 | 6.5.4 | Actualizar San Benito Abad (Sucre) |  | 1d | 2014-05-22 | 2014-05-22 | 363 | 17d | 0d |  | Perito Avaluador [50%]; Analistas SIG [50%]; Experto Social [10%] | 12.8h | 2,123,960.7 | 1 día | sáb 24/05/14 | sáb 24/05/14 |
| 378 | 6.5.5 | Actualizar Ayapel (Córdoba) |  | 2d | 2014-04-29 | 2014-04-30 | 364 | 35d | 0d |  | Perito Avaluador [50%]; Analistas SIG [50%]; Experto Social [10%] | 25.6h | 4,247,921.39 | 2 días | sáb 03/05/14 | vie 02/05/14 |
| 379 | 6.5.6 | Actualizar Nechi (Antioquia) |  | 1d | 2014-05-14 | 2014-05-14 | 365 | 24d | 0d |  | Perito Avaluador [50%]; Analistas SIG [50%]; Experto Social [10%] | 12.8h | 2,123,960.7 | 1 día | vie 16/05/14 | vie 16/05/14 |
| 380 | 6.5.7 | Actualizar San Jacinto del Cauca (Bolívar) |  | 1d | 2014-05-30 | 2014-05-30 | 366 | 10d | 0d |  | Perito Avaluador [50%]; Analistas SIG [50%]; Experto Social [10%] | 12.8h | 2,123,960.7 | 1 día | mar 03/06/14 | mar 03/06/14 |
| 381 | 6.5.8 | Actualizar Guaranda (Sucre) |  | 1d | 2014-04-22 | 2014-04-22 | 367 | 42d | 0d |  | Perito Avaluador [50%]; Analistas SIG [50%]; Experto Social [10%] | 12.8h | 2,123,960.7 | 1 día | jue 24/04/14 | jue 24/04/14 |
| 382 | 6.5.9 | Actualizar Majagual (Sucre) |  | 2d | 2014-05-06 | 2014-05-07 | 368 | 30d | 0d |  | Perito Avaluador [50%]; Analistas SIG [50%]; Experto Social [10%] | 38.4h | 6,371,882.09 | 2 días | vie 09/05/14 | jue 08/05/14 |
| 383 | 6.5.10 | Actualizar Achí (Bolívar) |  | 1d | 2014-05-17 | 2014-05-17 | 369 | 21d | 0d |  | Perito Avaluador [50%]; Analistas SIG [50%]; Experto Social [10%] | 12.8h | 2,123,960.7 | 1 día | mar 20/05/14 | mar 20/05/14 |
| 384 | 6.5.11 | Actualizar Sucre (Sucre) |  | 1d | 2014-05-31 | 2014-05-31 | 370 | 14d | 0d |  | Perito Avaluador [50%]; Analistas SIG [50%]; Experto Social [10%] | 12.8h | 2,123,960.7 | 1 día | mié 04/06/14 | mié 04/06/14 |
| 385 | 6.5.12 | Generar informe y mapa final de zonas físicas y económicas |  | 2d | 2014-06-06 | 2014-06-07 | 384FS-5d, 374FS-5d, 375, 376, 377, 378, 379, 380, 381, 382, 383 | 6d | 0d |  | Perito Avaluador [60%]; Analistas SIG [60%]; Auxiliar Administrativo [60%]; Director de proyecto [10%] | 237.6h | 23,363,567.65 | 2 días | mar 10/06/14 | lun 09/06/14 |
| 386 | 6.5.13 | Informe y Mapa final de zonas físicas y económicas generado | milestone | 0d | 2014-06-07 | 2014-06-07 | 385 | 6d | 1d |  |  |  |  | 0 días | mar 10/06/14 | mar 10/06/14 |
| 387 | 6.6 | Generar informe final de investigación de mercado y base de datos geográfica |  | 10d | 2014-05-30 | 2014-06-11 | 386SS-8d, 330 | 3d | 0d |  | Perito Avaluador [50%]; Auxiliar Administrativo [50%]; Analistas de Información [50%]; Profesional de apoyo sistemas [40%] | 211.2h | 23,363,567.65 | 10 días | vie 13/06/14 | mar 03/06/14 |
| 388 | 6.7 | Base de datos geográfica (Entregable 5) entregado | milestone | 0d | 2014-06-11 | 2014-06-11 | 387, 358 | 3d | 0d |  |  |  |  | 0 días | vie 13/06/14 | vie 13/06/14 |
| 389 | 7 | **Fase de consolidación** |  | 130d | 2014-01-28 | 2014-07-05 |  | 4d |  |  |  | 1251.2h | 180,536,659.1 | 130 días | sáb 05/07/14 | mar 28/01/14 |
| 390 | 7.1 | **Consolidación de información de informes mensuales** |  | 130d | 2014-01-28 | 2014-07-05 |  | 4d |  |  |  | 344h | 91,330,309.9 | 130 días | sáb 05/07/14 | mar 28/01/14 |
| 391 | 7.1.1 | Consolidar información de informe mensual 1 |  | 5d | 2014-01-28 | 2014-02-01 |  | 129d | 125d | start no earlier than 2014-01-28 | Auxiliar Administrativo | 48h | 12,743,764.17 | 5 días | sáb 01/02/14 | mar 28/01/14 |
| 392 | 7.1.2 | Consolidar información de informe mensual 2 |  | 5d | 2014-03-04 | 2014-03-08 |  | 99d | 95d | finish no earlier than 2014-03-08 | Auxiliar Administrativo | 56h | 14,867,724.87 | 5 días | sáb 08/03/14 | mar 04/03/14 |
| 393 | 7.1.3 | Consolidar información de informe mensual 3 |  | 5d | 2014-04-01 | 2014-04-05 |  | 76d | 72d | finish no earlier than 2014-04-05 | Auxiliar Administrativo | 64h | 16,991,685.56 | 5 días | sáb 05/04/14 | mar 01/04/14 |
| 394 | 7.1.4 | Consolidar información de informe mensual 4 |  | 5d | 2014-04-28 | 2014-05-03 |  | 55d | 51d | finish no earlier than 2014-05-03 | Auxiliar Administrativo | 56h | 14,867,724.87 | 5 días | sáb 03/05/14 | lun 28/04/14 |
| 395 | 7.1.5 | Consolidar información de informe mensual 5 |  | 5d | 2014-06-03 | 2014-06-07 |  | 26d | 22d | finish no earlier than 2014-06-07 | Auxiliar Administrativo | 56h | 14,867,724.87 | 5 días | sáb 07/06/14 | mar 03/06/14 |
| 396 | 7.1.6 | Consolidar información de informe mensual 6 |  | 5d | 2014-07-01 | 2014-07-05 |  | 4d | 0d | finish no earlier than 2014-07-05 | Auxiliar Administrativo | 64h | 16,991,685.56 | 5 días | sáb 05/07/14 | mar 01/07/14 |
| 397 | 7.1.7 | Información manejada durante el proyecto consolidada | milestone | 0d | 2014-07-05 | 2014-07-05 | 396, 391, 392, 393, 394, 395 | 4d | 0d |  |  |  |  | 0 días | sáb 05/07/14 | sáb 05/07/14 |
| 398 | 7.2 | Generar Informe final de resultados del proyecto |  | 17d | 2014-06-11 | 2014-07-02 | 388FS-1d | 3d | 0d |  | Director de proyecto [20%]; Gerente de Operaciones [50%]; Perito Avaluador [50%]; Experto Social [50%]; Auxiliar Administrativo [50%] | 453.6h | 44,603,174.6 | 17 días | vie 04/07/14 | vie 13/06/14 |
| 399 | 7.3 | Informe final de resultados del proyecto entregado | milestone | 0d | 2014-07-05 | 2014-07-05 | 398, 397 | 4d |  |  |  |  |  | 0 días | sáb 05/07/14 | sáb 05/07/14 |
| 400 | 7.4 | Generar Informe de resultado de valoración de predios |  | 17d | 2014-06-11 | 2014-07-02 | 388FS-1d | 3d | 0d |  | Director de proyecto [20%]; Gerente de Operaciones [50%]; Perito Avaluador [50%]; Experto Social [50%]; Auxiliar Administrativo [50%] | 453.6h | 44,603,174.6 | 17 días | vie 04/07/14 | vie 13/06/14 |
| 401 | 7.5 | Informe final del estudio e informe de precios comerciales (Entregable 6) entregado | milestone | 0d | 2014-07-02 | 2014-07-02 | 398, 400 | 3d | 0d |  |  |  |  | 0 días | vie 04/07/14 | vie 04/07/14 |

Notes:
- 388: Entregable 5 / La base de datos geográfica con la actualización de zonas geoeconómicas de toda la región de la Mojana.~ ~~
- 401: Entregable 6 / Un informe sobre precios comerciales, la metodología empleada y recomendaciones al FA para los procesos de posibles adquisiciones prediales y análisis costo -beneficio.~Un informe final del estudio.

| ID | WBS | Task | Type | Duration | Start | Finish | Predecessors | Total slack | Resources | Work | Cost | Text27 | Text29 | Text30 |
| --- | --- | --- | --- | --- | --- | --- | --- | --- | --- | --- | --- | --- | --- | --- |
| 402 | 8 | **Fase de apoyo** |  | 109d | 2014-02-05 | 2014-06-17 |  | 18d |  | 403.2h | 21,239,606.96 | 155 días | mar 08/07/14 | lun 30/12/13 |
| 403 | 8.1 | **Soporte de configuraciones** |  | 5d | 2014-02-05 | 2014-02-10 |  | 122d |  | 152h | 21,239,606.96 | 5 días | lun 10/02/14 | mié 05/02/14 |
| 404 | 8.1.1 | Configurar servicios geográficos y simbología |  | 5d | 2014-02-05 | 2014-02-10 | 36FS-1d | 122d | Profesional de apoyo sistemas [40%]; Analistas SIG [40%]; Coordinador de Información [50%] | 76h | 10,619,803.48 | 5 días | lun 10/02/14 | mié 05/02/14 |
| 405 | 8.1.2 | Configurar variables de consulta geográfica/alfanumérica |  | 5d | 2014-02-05 | 2014-02-10 | 36FS-1d | 122d | Profesional de apoyo sistemas [40%]; Analistas SIG [40%]; Coordinador de Información [50%] | 76h | 10,619,803.48 | 5 días | lun 10/02/14 | mié 05/02/14 |
| 406 | 8.2 | **Soporte general de sistemas** |  | 108d | 2014-02-06 | 2014-06-17 |  | 18d |  | 251.2h |  | 130 días | mar 08/07/14 | jue 30/01/14 |
| 407 | 8.2.1 | Soporte a entregable 2 |  | 10d | 2014-02-06 | 2014-02-17 | 38FS-5d | 116d | Coordinador Desarrollo [20%] | 251.2h |  | 130 días | mar 08/07/14 | jue 30/01/14 |
| 408 | 8.2.2 | Soporte a entregable 3 |  | 10d | 2014-03-03 | 2014-03-13 | 106FS-5d | 95d |  |  |  |  |  |  |
| 409 | 8.2.3 | Soporte a entregable 4 |  | 10d | 2014-05-31 | 2014-06-12 | 276FS-5d | 22d |  |  |  |  |  |  |
| 410 | 8.2.4 | Soporte a entregable 5 |  | 10d | 2014-06-06 | 2014-06-17 | 388FS-5d | 18d |  |  |  |  |  |  |
| 411 | 9 | **Fase de reuniones y entregas** |  | 157d | 2013-12-30 | 2014-07-10 |  | 0d |  | 750.4h | 82,834,467.15 | 142 días | jue 10/07/14 | sáb 18/01/14 |
| 412 | 9.1 | **Entregas parciales a supervisor** |  | 134d | 2013-12-30 | 2014-06-11 |  | 23d |  |  |  | 109 días | vie 13/06/14 | vie 31/01/14 |
| 413 | 9.1.1 | Inventario de información (por municipio) entregado | milestone | 0d | 2014-01-31 | 2014-01-31 | 28 | 130d |  |  |  | 0 días | vie 31/01/14 | vie 31/01/14 |
| 414 | 9.1.2 | Reporte de diagnostico alfanumérico entregado | milestone | 0d | 2013-12-30 | 2013-12-30 |  | 157d |  |  |  | 0 días | mié 12/02/14 | mié 12/02/14 |
| 415 | 9.1.3 | Información cartográfica y temática actualizada de la Mojana entregada | milestone | 0d | 2014-03-14 | 2014-03-14 | 125 | 94d |  |  |  | 0 días | mar 04/03/14 | mar 04/03/14 |
| 416 | 9.1.4 | Informe final de cruce entregado | milestone | 0d | 2014-03-06 | 2014-03-06 | 105 | 101d |  |  |  | 0 días | sáb 22/02/14 | sáb 22/02/14 |
| 417 | 9.1.5 | Documento y mapa de tipificación para muestra entregado | milestone | 0d | 2014-04-16 | 2014-04-16 | 180 | 67d |  |  |  | 0 días | jue 20/03/14 | jue 20/03/14 |
| 418 | 9.1.6 | Diagnóstico técnico jurídico inicial entregado | milestone | 0d | 2014-03-17 | 2014-03-17 | 262 | 92d |  |  |  | 0 días | mié 05/03/14 | mié 05/03/14 |
| 419 | 9.1.7 | Mapa actualizado de zonas físicas entregado | milestone | 0d | 2014-03-28 | 2014-03-28 | 287 | 83d |  |  |  | 0 días | sáb 08/03/14 | sáb 08/03/14 |
| 420 | 9.1.8 | Informe de Análisis de tipificación para muestra de inventario de mercado Entregado | milestone | 0d | 2014-03-22 | 2014-03-22 | 294 | 87d |  |  |  | 0 días | vie 21/03/14 | vie 21/03/14 |
| 421 | 9.1.9 | **Zonas geoeconómicas ajustadas y actualizadas** |  | 41d | 2014-04-22 | 2014-06-11 |  | 23d |  |  |  | 41 días | vie 13/06/14 | jue 24/04/14 |
| 422 | 9.1.9.1 | Zonas de Magangué (Bolívar) entregadas | milestone | 0d | 2014-06-11 | 2014-06-11 | 374 | 23d |  |  |  | 0 días | vie 13/06/14 | vie 13/06/14 |
| 423 | 9.1.9.2 | Zonas de San Marcos (Sucre) entregadas | milestone | 0d | 2014-05-09 | 2014-05-09 | 375 | 50d |  |  |  | 0 días | lun 12/05/14 | lun 12/05/14 |
| 424 | 9.1.9.3 | Zonas de Caimito (Sucre) entregadas | milestone | 0d | 2014-05-13 | 2014-05-13 | 376 | 47d |  |  |  | 0 días | jue 15/05/14 | jue 15/05/14 |
| 425 | 9.1.9.4 | Zonas de San Benito Abad (Sucre) entregadas | milestone | 0d | 2014-05-22 | 2014-05-22 | 377 | 39d |  |  |  | 0 días | sáb 24/05/14 | sáb 24/05/14 |
| 426 | 9.1.9.5 | Zonas de Ayapel (Córdoba) entregadas | milestone | 0d | 2014-04-30 | 2014-04-30 | 378 | 57d |  |  |  | 0 días | sáb 03/05/14 | sáb 03/05/14 |
| 427 | 9.1.9.6 | Zonas de Nechi (Antioquia) entregadas | milestone | 0d | 2014-05-14 | 2014-05-14 | 379 | 46d |  |  |  | 0 días | vie 16/05/14 | vie 16/05/14 |
| 428 | 9.1.9.7 | Zonas de San Jacinto del Cauca (Bolívar) entregadas | milestone | 0d | 2014-05-30 | 2014-05-30 | 380 | 32d |  |  |  | 0 días | mar 03/06/14 | mar 03/06/14 |
| 429 | 9.1.9.8 | Zonas de Guaranda (Sucre) entregadas | milestone | 0d | 2014-04-22 | 2014-04-22 | 381 | 64d |  |  |  | 0 días | jue 24/04/14 | jue 24/04/14 |
| 430 | 9.1.9.9 | Zonas de Majagual (Sucre) entregadas | milestone | 0d | 2014-05-07 | 2014-05-07 | 382 | 52d |  |  |  | 0 días | vie 09/05/14 | vie 09/05/14 |
| 431 | 9.1.9.10 | Zonas de Achí (Bolívar) entregadas | milestone | 0d | 2014-05-17 | 2014-05-17 | 383 | 43d |  |  |  | 0 días | mar 20/05/14 | mar 20/05/14 |
| 432 | 9.1.9.11 | Zonas de Sucre (Sucre) entregadas | milestone | 0d | 2014-05-31 | 2014-05-31 | 384 | 31d |  |  |  | 0 días | mié 04/06/14 | mié 04/06/14 |

| ID | WBS | Task | Type | Duration | Start | Finish | Predecessors | Total slack | Free slack | Resources | Work | Cost | Text27 | Text29 | Text30 |
| --- | --- | --- | --- | --- | --- | --- | --- | --- | --- | --- | --- | --- | --- | --- | --- |
| 433 | 9.2 | **Entregas y pagos** |  | 132d | 2014-01-27 | 2014-07-07 |  | 0d |  |  | 716.8h | 82,834,467.15 | 134 días | mié 09/07/14 | lun 27/01/14 |
| 434 | 9.2.1 | **Primer pago 10% - La Metodología detallada del trabajo** |  | 7d | 2014-01-27 | 2014-02-03 |  | 0d |  |  | 0.8h |  | 7 días | lun 03/02/14 | lun 27/01/14 |
| 435 | 9.2.1.1 | Entregar plan de trabajo a supervisor |  | 1d | 2014-01-27 | 2014-01-27 | 19FS-1d | 0d |  | Gerente de Operaciones |  |  | 1 día | lun 27/01/14 | lun 27/01/14 |
| 436 | 9.2.1.2 | Aprobar pago por supervisor |  | 6d | 2014-01-28 | 2014-02-03 | 435 | 128d | 0d | Supervisor FONDO [10%] | 0.8h |  | 6 días | lun 03/02/14 | mar 28/01/14 |
| 437 | 9.2.1.3 | Radicar factura | milestone | 0d | 2014-02-03 | 2014-02-03 | 436 | 128d |  |  |  |  | 0 días | lun 03/02/14 | lun 03/02/14 |
| 438 | 9.2.2 | **Segundo pago 20% - 2. La base de datos geográfica** |  | 5d | 2014-02-12 | 2014-02-17 |  | 116d |  |  | 96.8h | 12,743,764.18 | 5 días | lun 17/02/14 | mié 12/02/14 |
| 439 | 9.2.2.1 | Entregar Base de datos a supervisor |  | 4d | 2014-02-12 | 2014-02-15 | 38 | 116d | 0d | Gerente de Operaciones [50%]; Director de proyecto [20%]; Experto Catastral [20%]; Auxiliar Administrativo [20%]; Experto Social [20%]; Coordinador de Información [30%] | 96h | 10,619,803.48 | 4 días | sáb 15/02/14 | mié 12/02/14 |
| 440 | 9.2.2.2 | Aprobar pago por supervisor |  | 1d | 2014-02-17 | 2014-02-17 | 439 | 116d | 0d | Supervisor FONDO [10%] | 0.8h | 2,123,960.7 | 1 día | lun 17/02/14 | lun 17/02/14 |
| 441 | 9.2.2.3 | Radicar factura | milestone | 0d | 2014-02-17 | 2014-02-17 | 440 | 116d |  |  |  |  | 0 días | lun 17/02/14 | lun 17/02/14 |
| 442 | 9.2.3 | **Tercer pago 20% - El documento con el análisis de la información** |  | 9d | 2014-03-08 | 2014-03-18 |  | 91d |  |  | 118.4h | 16,991,685.57 | 9 días | vie 07/03/14 | mié 26/02/14 |
| 443 | 9.2.3.1 | Entregar documento de análisis a supervisor |  | 1d | 2014-03-08 | 2014-03-08 | 106 | 91d | 0d | Gerente de Operaciones [50%]; Director de proyecto [20%]; Experto Catastral [20%]; Auxiliar Administrativo [20%]; Coordinador de Información [20%] | 117.6h | 14,867,724.87 | 1 día | mié 26/02/14 | mié 26/02/14 |
| 444 | 9.2.3.2 | Aprobar pago por supervisor |  | 8d | 2014-03-10 | 2014-03-18 | 443 | 91d | 0d | Supervisor FONDO [10%] | 0.8h | 2,123,960.7 | 8 días | vie 07/03/14 | jue 27/02/14 |
| 445 | 9.2.3.3 | Radicar factura | milestone | 0d | 2014-03-18 | 2014-03-18 | 444 | 91d |  |  |  |  | 0 días | vie 07/03/14 | vie 07/03/14 |
| 446 | 9.2.4 | **Cuarto pago 20% - La base de datos organizada** |  | 6d | 2014-06-07 | 2014-06-13 |  | 21d |  |  | 104.8h | 12,743,764.18 | 6 días | sáb 17/05/14 | lun 12/05/14 |
| 447 | 9.2.4.1 | Entregar Base de datos a supervisor |  | 1d | 2014-06-07 | 2014-06-07 | 276 | 21d | 0d | Gerente de Operaciones [50%]; Director de proyecto [20%]; Experto Catastral [20%]; Auxiliar Administrativo [20%]; Analistas de Información [50%]; Coordinador de Información [20%] | 104h | 10,619,803.48 | 1 día | lun 12/05/14 | lun 12/05/14 |
| 448 | 9.2.4.2 | Aprobar pago por supervisor |  | 4d | 2014-06-09 | 2014-06-12 | 447 | 21d | 0d | Supervisor FONDO [10%] | 0.8h | 2,123,960.7 | 4 días | vie 16/05/14 | mar 13/05/14 |
| 449 | 9.2.4.3 | Radicar factura | milestone | 1d | 2014-06-13 | 2014-06-13 | 448 | 21d |  |  |  |  | 1 día | sáb 17/05/14 | sáb 17/05/14 |
| 450 | 9.2.5 | **Quinto pago 20% - La base de datos geográfica con la actualización de zonas geoeconómicas** |  | 6d | 2014-06-12 | 2014-06-18 |  | 17d |  |  | 256h | 25,487,528.35 | 6 días | vie 20/06/14 | sáb 14/06/14 |
| 451 | 9.2.5.1 | Entregar informe final de investigación de mercado y base de datos geográfica |  | 1d | 2014-06-12 | 2014-06-12 | 385, 388 | 17d | 0d | Gerente de Operaciones [50%]; Director de proyecto [20%]; Experto Catastral [20%]; Auxiliar Administrativo [20%]; Perito Avaluador [20%] | 255.2h | 23,363,567.65 | 1 día | sáb 14/06/14 | sáb 14/06/14 |
| 452 | 9.2.5.2 | Aprobar pago por supervisor |  | 5d | 2014-06-13 | 2014-06-18 | 451 | 17d | 0d | Supervisor FONDO [10%] | 0.8h | 2,123,960.7 | 5 días | vie 20/06/14 | lun 16/06/14 |
| 453 | 9.2.5.3 | Radicar factura | milestone | 0d | 2014-06-18 | 2014-06-18 | 452 | 17d |  |  |  |  | 0 días | vie 20/06/14 | vie 20/06/14 |
| 454 | 9.2.6 | **Sexto pago 10% - Un informe sobre precios comerciales** |  | 4d | 2014-07-03 | 2014-07-07 |  | 3d |  |  | 140h | 14,867,724.87 | 4 días | mié 09/07/14 | sáb 05/07/14 |
| 455 | 9.2.6.1 | Entregar informe al supervisor para pago |  | 1d | 2014-07-03 | 2014-07-03 | 401 | 3d | 0d | Gerente de Operaciones [50%]; Director de proyecto [20%]; Experto Catastral [20%]; Auxiliar Administrativo [20%]; Perito Avaluador [20%] | 139.2h | 12,743,764.17 | 1 día | sáb 05/07/14 | sáb 05/07/14 |
| 456 | 9.2.6.2 | Aprobar pago por supervisor |  | 3d | 2014-07-04 | 2014-07-07 | 455 | 3d | 0d | Supervisor FONDO [10%] | 0.8h | 2,123,960.7 | 3 días | mié 09/07/14 | lun 07/07/14 |
| 457 | 9.2.6.3 | Radicar factura | milestone | 0d | 2014-07-07 | 2014-07-07 | 456 | 3d |  |  |  |  | 0 días | mié 09/07/14 | mié 09/07/14 |

| ID | WBS | Task | Duration | Start | Finish | Total slack | Constraint | Text27 | Text29 | Text30 |
| --- | --- | --- | --- | --- | --- | --- | --- | --- | --- | --- |
| 458 | 9.3 | **Preparación de informes** | 141d | 2014-01-18 | 2014-07-09 | 1d |  | 141 días | mié 09/07/14 | sáb 18/01/14 |
| 459 | 9.3.1 | **Preparación de informes quincenales** | 140d | 2014-01-18 | 2014-07-08 | 2d |  | 140 días | mar 08/07/14 | sáb 18/01/14 |
| 460 | 9.3.1.1 | Preparar informe quincenal 1 | 3d | 2014-01-18 | 2014-01-21 | 139d | finish no earlier than 2014-01-21 | 3 días | mar 21/01/14 | sáb 18/01/14 |
| 461 | 9.3.1.2 | Preparar informe quincenal 2 | 3d | 2014-02-08 | 2014-02-11 | 121d | finish no earlier than 2014-02-11 | 3 días | mar 11/02/14 | sáb 08/02/14 |
| 462 | 9.3.1.3 | Preparar informe quincenal 3 | 6d | 2014-02-19 | 2014-02-25 | 109d | finish no earlier than 2014-02-25 | 6 días | mar 25/02/14 | mié 19/02/14 |
| 463 | 9.3.1.4 | Preparar informe quincenal 4 | 2d | 2014-03-10 | 2014-03-11 | 97d | finish no earlier than 2014-03-11 | 2 días | mar 11/03/14 | lun 10/03/14 |
| 464 | 9.3.1.5 | Preparar informe quincenal 5 | 2d | 2014-03-22 | 2014-03-25 | 86d | finish no earlier than 2014-03-25 | 2 días | mar 25/03/14 | sáb 22/03/14 |
| 465 | 9.3.1.6 | Preparar informe quincenal 6 | 2d | 2014-04-07 | 2014-04-08 | 74d | finish no earlier than 2014-04-08 | 2 días | mar 08/04/14 | lun 07/04/14 |
| 466 | 9.3.1.7 | Preparar informe quincenal 7 | 2d | 2014-04-21 | 2014-04-22 | 64d | finish no earlier than 2014-04-22 | 2 días | mar 22/04/14 | lun 21/04/14 |
| 467 | 9.3.1.8 | Preparar informe quincenal 8 | 2d | 2014-05-05 | 2014-05-06 | 53d | finish no earlier than 2014-05-06 | 2 días | mar 06/05/14 | lun 05/05/14 |
| 468 | 9.3.1.9 | Preparar informe quincenal 9 | 2d | 2014-05-19 | 2014-05-20 | 41d | finish no earlier than 2014-05-20 | 2 días | mar 20/05/14 | lun 19/05/14 |
| 469 | 9.3.1.10 | Preparar informe quincenal 10 | 2d | 2014-06-09 | 2014-06-10 | 24d | finish no earlier than 2014-06-10 | 2 días | mar 10/06/14 | lun 09/06/14 |
| 470 | 9.3.1.11 | Preparar informe quincenal 11 | 2d | 2014-06-21 | 2014-06-24 | 13d | finish no earlier than 2014-06-24 | 2 días | mar 24/06/14 | sáb 21/06/14 |
| 471 | 9.3.1.12 | Preparar informe quincenal 12 | 2d | 2014-07-07 | 2014-07-08 | 2d | finish no earlier than 2014-07-08 | 2 días | mar 08/07/14 | lun 07/07/14 |
| 472 | 9.3.2 | **Preparación Informes mensuales** | 124d | 2014-02-06 | 2014-07-08 | 2d |  | 124 días | mar 08/07/14 | jue 06/02/14 |
| 473 | 9.3.2.1 | Preparar Informe mensual 1 | 5d | 2014-02-06 | 2014-02-11 | 121d | finish no earlier than 2014-02-11 | 5 días | mar 11/02/14 | jue 06/02/14 |
| 474 | 9.3.2.2 | Preparar Informe mensual 2 | 5d | 2014-03-06 | 2014-03-11 | 97d | finish no earlier than 2014-03-11 | 5 días | mar 11/03/14 | jue 06/03/14 |
| 475 | 9.3.2.3 | Preparar Informe mensual 3 | 5d | 2014-04-03 | 2014-04-08 | 74d | finish no earlier than 2014-04-08 | 5 días | mar 08/04/14 | jue 03/04/14 |
| 476 | 9.3.2.4 | Preparar Informe mensual 4 | 5d | 2014-04-30 | 2014-05-06 | 53d | finish no earlier than 2014-05-06 | 5 días | mar 06/05/14 | mié 30/04/14 |
| 477 | 9.3.2.5 | Preparar Informe mensual 5 | 5d | 2014-06-05 | 2014-06-10 | 24d | finish no earlier than 2014-06-10 | 5 días | mar 10/06/14 | jue 05/06/14 |
| 478 | 9.3.2.6 | Preparar Informe mensual 6 | 5d | 2014-07-03 | 2014-07-08 | 2d | finish no earlier than 2014-07-08 | 5 días | mar 08/07/14 | jue 03/07/14 |
| 479 | 9.3.3 | **Preparación presentación mensual a comité de supervisión** | 121d | 2014-02-11 | 2014-07-09 | 1d |  | 121 días | mié 09/07/14 | mar 11/02/14 |
| 480 | 9.3.3.1 | Preparar presentación a comité de supervisión 1 | 2d | 2014-02-11 | 2014-02-12 | 120d | finish no earlier than 2014-02-12 | 2 días | mié 12/02/14 | mar 11/02/14 |
| 481 | 9.3.3.2 | Preparar presentación a comité de supervisión 2 | 2d | 2014-03-11 | 2014-03-12 | 96d | finish no earlier than 2014-03-12 | 2 días | mié 12/03/14 | mar 11/03/14 |
| 482 | 9.3.3.3 | Preparar presentación a comité de supervisión 3 | 2d | 2014-04-08 | 2014-04-09 | 73d | finish no earlier than 2014-04-09 | 2 días | mié 09/04/14 | mar 08/04/14 |
| 483 | 9.3.3.4 | Preparar presentación a comité de supervisión 4 | 2d | 2014-05-06 | 2014-05-07 | 52d | finish no earlier than 2014-05-07 | 2 días | mié 07/05/14 | mar 06/05/14 |
| 484 | 9.3.3.5 | Preparar presentación a comité de supervisión 5 | 2d | 2014-06-10 | 2014-06-11 | 23d | finish no earlier than 2014-06-11 | 2 días | mié 11/06/14 | mar 10/06/14 |
| 485 | 9.3.3.6 | Preparar presentación a comité de supervisión 6 | 2d | 2014-07-08 | 2014-07-09 | 1d | finish no earlier than 2014-07-09 | 2 días | mié 09/07/14 | mar 08/07/14 |

| ID | WBS | Task | Duration | Start | Finish | Total slack | Constraint | Resources | Work | Text27 | Text29 | Text30 |
| --- | --- | --- | --- | --- | --- | --- | --- | --- | --- | --- | --- | --- |
| 486 | 9.4 | **Reuniones quincenales con la supervisión** | 138d | 2014-01-22 | 2014-07-09 | 0d |  |  | 33.6h | 138 días | mié 09/07/14 | mié 22/01/14 |
| 487 | 9.4.1 | Asistir a reunión quincenal con la supervisión 1 | 1d | 2014-01-22 | 2014-01-22 | 0d | start no earlier than 2014-01-22 | Director de proyecto [20%]; Gerente de Operaciones [20%] |  | 1 día | mié 22/01/14 | mié 22/01/14 |
| 488 | 9.4.2 | Asistir a reunión quincenal con la supervisión 2 | 1d | 2014-02-12 | 2014-02-12 | 120d | finish no earlier than 2014-02-12 | Director de proyecto [20%]; Gerente de Operaciones [20%] | 1.6h | 1 día | mié 12/02/14 | mié 12/02/14 |
| 489 | 9.4.3 | Asistir a reunión quincenal con la supervisión 3 | 1d | 2014-02-26 | 2014-02-26 | 108d | finish no earlier than 2014-02-26 | Director de proyecto [20%]; Gerente de Operaciones [20%] | 3.2h | 1 día | mié 26/02/14 | mié 26/02/14 |
| 490 | 9.4.4 | Asistir a reunión quincenal con la supervisión 4 | 1d | 2014-03-12 | 2014-03-12 | 96d | finish no earlier than 2014-03-12 | Director de proyecto [20%]; Gerente de Operaciones [20%] | 3.2h | 1 día | mié 12/03/14 | mié 12/03/14 |
| 491 | 9.4.5 | Asistir a reunión quincenal con la supervisión 5 | 1d | 2014-03-26 | 2014-03-26 | 85d | finish no earlier than 2014-03-26 | Director de proyecto [20%]; Gerente de Operaciones [20%] | 3.2h | 1 día | mié 26/03/14 | mié 26/03/14 |
| 492 | 9.4.6 | Asistir a reunión quincenal con la supervisión 6 | 1d | 2014-04-09 | 2014-04-09 | 73d | finish no earlier than 2014-04-09 | Director de proyecto [20%]; Gerente de Operaciones [20%] | 3.2h | 1 día | mié 09/04/14 | mié 09/04/14 |
| 493 | 9.4.7 | Asistir a reunión quincenal con la supervisión 7 | 1d | 2014-04-23 | 2014-04-23 | 63d | finish no earlier than 2014-04-23 | Director de proyecto [20%]; Gerente de Operaciones [20%] | 3.2h | 1 día | mié 23/04/14 | mié 23/04/14 |
| 494 | 9.4.8 | Asistir a reunión quincenal con la supervisión 8 | 1d | 2014-05-07 | 2014-05-07 | 52d | finish no earlier than 2014-05-07 | Director de proyecto [20%]; Gerente de Operaciones [20%] | 3.2h | 1 día | mié 07/05/14 | mié 07/05/14 |
| 495 | 9.4.9 | Asistir a reunión quincenal con la supervisión 9 | 1d | 2014-05-21 | 2014-05-21 | 40d | finish no earlier than 2014-05-21 | Director de proyecto [20%]; Gerente de Operaciones [20%] | 3.2h | 1 día | mié 21/05/14 | mié 21/05/14 |
| 496 | 9.4.10 | Asistir a reunión quincenal con la supervisión 10 | 1d | 2014-06-11 | 2014-06-11 | 23d | finish no earlier than 2014-06-11 | Director de proyecto [20%]; Gerente de Operaciones [20%] | 3.2h | 1 día | mié 11/06/14 | mié 11/06/14 |
| 497 | 9.4.11 | Asistir a reunión quincenal con la supervisión 11 | 1d | 2014-06-25 | 2014-06-25 | 12d | finish no earlier than 2014-06-25 | Director de proyecto [20%]; Gerente de Operaciones [20%] | 3.2h | 1 día | mié 25/06/14 | mié 25/06/14 |
| 498 | 9.4.12 | Asistir a reunión quincenal con la supervisión 12 | 1d | 2014-07-09 | 2014-07-09 | 1d | finish no earlier than 2014-07-09 | Director de proyecto [20%]; Gerente de Operaciones [20%] | 3.2h | 1 día | mié 09/07/14 | mié 09/07/14 |
| 499 | 9.5 | **Informes mensuales** | 120d | 2014-02-12 | 2014-07-09 | 1d |  |  |  | 120 días | mié 09/07/14 | mié 12/02/14 |
| 500 | 9.5.1 | Presentar informe mensual 1 | 1d | 2014-02-12 | 2014-02-12 | 120d | finish no earlier than 2014-02-12 |  |  | 1 día | mié 12/02/14 | mié 12/02/14 |
| 501 | 9.5.2 | Presentar informe mensual 2 | 1d | 2014-03-12 | 2014-03-12 | 96d | finish no earlier than 2014-03-12 |  |  | 1 día | mié 12/03/14 | mié 12/03/14 |
| 502 | 9.5.3 | Presentar informe mensual 3 | 1d | 2014-04-09 | 2014-04-09 | 73d | finish no earlier than 2014-04-09 |  |  | 1 día | mié 09/04/14 | mié 09/04/14 |
| 503 | 9.5.4 | Presentar informe mensual 4 | 1d | 2014-05-07 | 2014-05-07 | 52d | finish no earlier than 2014-05-07 |  |  | 1 día | mié 07/05/14 | mié 07/05/14 |
| 504 | 9.5.5 | Presentar informe mensual 5 | 1d | 2014-06-11 | 2014-06-11 | 23d | finish no earlier than 2014-06-11 |  |  | 1 día | mié 11/06/14 | mié 11/06/14 |
| 505 | 9.5.6 | Presentar informe mensual 6 | 1d | 2014-07-09 | 2014-07-09 | 1d | finish no earlier than 2014-07-09 |  |  | 1 día | mié 09/07/14 | mié 09/07/14 |
| 506 | 9.6 | **Reuniones mensuales con comité de supervisión** | 120d | 2014-02-13 | 2014-07-10 | 0d |  |  |  | 120 días | jue 10/07/14 | jue 13/02/14 |
| 507 | 9.6.1 | Asistir a reunión mensual con comité de supervisión 1 | 1d | 2014-02-13 | 2014-02-13 | 119d | start no earlier than 2014-02-13 |  |  | 1 día | jue 13/02/14 | jue 13/02/14 |
| 508 | 9.6.2 | Asistir a reunión mensual con comité de supervisión 2 | 1d | 2014-03-13 | 2014-03-13 | 95d | start no earlier than 2014-03-13 |  |  | 1 día | jue 13/03/14 | jue 13/03/14 |
| 509 | 9.6.3 | Asistir a reunión mensual con comité de supervisión 3 | 1d | 2014-04-10 | 2014-04-10 | 72d | start no earlier than 2014-04-10 |  |  | 1 día | jue 10/04/14 | jue 10/04/14 |
| 510 | 9.6.4 | Asistir a reunión mensual con comité de supervisión 4 | 1d | 2014-05-08 | 2014-05-08 | 51d | start no earlier than 2014-05-08 |  |  | 1 día | jue 08/05/14 | jue 08/05/14 |
| 511 | 9.6.5 | Asistir a reunión mensual con comité de supervisión 5 | 1d | 2014-06-12 | 2014-06-12 | 22d | start no earlier than 2014-06-12 |  |  | 1 día | jue 12/06/14 | jue 12/06/14 |
| 512 | 9.6.6 | Asistir a reunión mensual con comité de supervisión 6 | 1d | 2014-07-10 | 2014-07-10 | 0d | start no earlier than 2014-07-10 |  |  | 1 día | jue 10/07/14 | jue 10/07/14 |
